# Plan de Ejecución del Programa

Schedule from MS Project, 2016-01-04 to 2022-12-30, costs in $.

## Calendars

- Estándar: Mon-Fri 09:00-13:00, 15:00-19:00; Sat-Sun off.

## Schedule

| ID | WBS | Task | Type | Duration | Start | Finish | Predecessors | Total slack | Free slack | Cost | Text5 | Text1 |
| --- | --- | --- | --- | --- | --- | --- | --- | --- | --- | --- | --- | --- |
| 1 | 0 | Inicio de la preparación del Programa de Saneamiento de los Distritos de Arraiján y La Chorrera - PSACH Fase I | milestone | 0d | 2016-04-04 | 2016-04-04 |  | 0d |  |  |  |  |
| 2 | 0 | **Actividades previas** |  | 263d | 2016-04-04 | 2017-04-05 |  | 0d |  |  |  |  |
| 3 | 0 | Misión de Identificación |  | 5d | 2016-04-04 | 2016-04-08 | 1 | 0d |  |  | MINSA/MEF/BID |  |
| 4 | 0 | Disponibilidad del Perfil del Proyecto |  | 1d | 2016-05-26 | 2016-05-26 | 3FS+33d | 0d |  |  | BID |  |
| 5 | 0 | Misión de Orientación |  | 5d | 2016-06-06 | 2016-06-10 | 4FS+6d | 0d |  |  | MINSA/MEF/BID |  |
| 6 | 0 | Misión de Análisis |  | 4d | 2016-08-16 | 2016-08-19 | 5FS+46d | 0d |  |  | MINSA/MEF/BID |  |
| 7 | 0 | Propuesta de Préstamo al Directorio del BID |  | 1d | 2016-09-01 | 2016-09-01 | 6FS+8d | 0d |  |  | BID |  |
| 8 | 0 | Negociación del contrato |  | 1d | 2016-10-14 | 2016-10-14 | 7FS+30d | 0d |  |  | MEF/BID |  |
| 9 | 0 | Consejo Económico Nacional |  | 1d | 2016-11-16 | 2016-11-16 | 8FS+22d | 0d |  |  | MINSA/MEF |  |
| 10 | 0 | Consejo de Gabinete |  | 1d | 2016-12-01 | 2016-12-01 | 9FS+10d | 0d |  |  | MINSA/MEF |  |
| 11 | 0 | Refrendo de la CGR |  | 1d | 2017-01-03 | 2017-01-03 | 10FS+22d | 0d |  |  | MINSA/MEF |  |
| 12 | 0 | Cumplimiento de Condiciones de Elegibilidad |  | 66d | 2017-01-04 | 2017-04-05 | 11 | 0d |  |  | UCPSP-MINSA |  |
| 13 | 0 | Inicio de la ejecución del PSACH Fase I | milestone | 0d | 2017-04-06 | 2017-04-06 | 12FS+1d | 0d |  |  |  |  |
| 14 | 1 | **Componente 1. Inversiones prioritarias** |  | 1825d | 2016-01-04 | 2022-12-30 |  | 0d |  | 613,214,141 |  |  |
| 15 | 1.1 | **Producto 1: Primer Módulo de la PTAR construida** |  | 1539d | 2016-01-04 | 2021-11-25 |  | 0d |  | 140,153,608 |  |  |
| 16 | 1.1.1 | **Actividades de coordinación y seguimiento de acuerdos entre autoridades del MINSA y propietarios del terreno para su adquisición** |  | 345d | 2016-04-04 | 2017-07-28 | 1 | 50d |  |  |  |  |
| 17 | 1.1.1.1 | Adquisciones de terrenos |  | 345d | 2016-04-04 | 2017-07-28 |  | 50d | 0d |  |  |  |
| 18 | 1.1.2 | **LPI_1. Contratación de firma para el diseño y construcción de obras** |  | 1101d | 2017-07-31 | 2021-10-18 |  | 50d |  | 129,771,859 |  |  |
| 19 | 1.1.2.1 | Etapa previa |  | 80d | 2017-07-31 | 2017-11-17 | 36, 17 | 50d | 0d |  | PM | PM |
| 20 | 1.1.2.2 | Etapa de contratación |  | 95d | 2017-11-20 | 2018-03-30 | 19 | 50d | 0d |  | PM y Adm. Pry | PM y Adm. Pry |
| 21 | 1.1.2.3 | Formalización del contrato |  | 66d | 2018-04-02 | 2018-07-02 | 20 | 50d | 0d |  | BID | BID |
| 22 | 1.1.2.6 | **Ejecución de contrato** |  | 860d | 2018-07-03 | 2021-10-18 |  | 50d |  |  |  |  |
| 23 | 1.1.2.6.1 | Elaboración del diseño final |  | 300d | 2018-07-03 | 2019-08-26 | 21 | 50d | 0d |  | Contratista | Contratista |
| 24 | 1.1.2.6.6 | Diseño de la PTAR Caimito elaborado | milestone | 0d | 2019-08-26 | 2019-08-26 | 23 | 874d |  |  |  |  |
| 25 | 1.1.1.6.3 | Construcción de la PTAR |  | 800d | 2018-09-25 | 2021-10-18 | 23SS+60d | 50d | 0d |  | Contratista | Contratista |
| 26 | 1.1.1.6.4 | PTAR Caimito construida | milestone | 0d | 2021-10-18 | 2021-10-18 | 25 | 50d | 0d |  |  |  |

| ID | WBS | Task | Type | Duration | Start | Finish | Predecessors | Total slack | Free slack | Cost | Text5 | Text1 |
| --- | --- | --- | --- | --- | --- | --- | --- | --- | --- | --- | --- | --- |
| 27 | 1.1.2.5 | **Pagos** |  | 860d | 2018-07-03 | 2021-10-18 |  | 314d |  | 129,771,859 |  |  |
| 28 | 1.1.2.5.1 | Pagos BID |  | 860d | 2018-07-03 | 2021-10-18 | 23SS | 314d | 0d | 40,000,000 | Adm. Financ. |  |
| 29 | 1.1.2.5.2 | Pagos AECID |  | 860d | 2018-07-03 | 2021-10-18 | 28SS | 314d | 0d | 23,000,000 | Adm. Financ. |  |
| 30 | 1.1.2.5.3 | Pago CAF |  | 860d | 2018-07-03 | 2021-10-18 | 29SS | 314d | 0d | 16,274,300 | Adm. Financ. |  |
| 31 | 1.1.2.5.4 | Pago CL |  | 860d | 2018-07-03 | 2021-10-18 | 30SS | 314d |  | 50,497,559 | Adm. Financ. |  |
| 32 | 1.1.3 | **SBCC_6. Contratación de firma consultora para la supervisión de diseños y obras** |  | 1539d | 2016-01-04 | 2021-11-25 |  | 0d |  | 10,381,749 |  |  |
| 33 | 1.1.3.1 | Etapa previa |  | 160d | 2016-01-04 | 2016-08-12 | 1FS-65d | 0d |  |  | Adm. Pry | Adm. Pry |
| 34 | 1.1.3.2 | Etapa de Expresión de interés |  | 45d | 2016-08-15 | 2016-10-14 | 33 | 50d | 0d |  | Gte. Leg. Y Contr. |  |
| 35 | 1.1.3.2 | Etapa de contratación |  | 110d | 2016-10-17 | 2017-03-17 | 34 | 50d | 0d |  | Adm. Pry | Adm. Pry |
| 36 | 1.1.3.4 | Formalización del contrato |  | 95d | 2017-03-20 | 2017-07-28 | 35 | 50d | 0d |  | Gte. Leg. Y Contr. |  |
| 37 | 1.1.3.5 | Ejecución de contrato |  | 1125d | 2017-08-04 | 2021-11-25 | 36FS+4d | 286d | 0d |  | PM | PM |
| 38 | 1.1.3.6 | **Pagos** |  | 1125d | 2017-08-04 | 2021-11-25 |  | 286d |  | 10,381,749 |  |  |
| 39 | 1.1.3.6.1 | Pagos BID |  | 1125d | 2017-08-04 | 2021-11-25 | 37SS | 286d | 0d | 8,308,915 | Adm. Financ. |  |
| 40 | 1.1.3.6.2 | Pagos CL |  | 1125d | 2017-08-04 | 2021-11-25 | 39SS | 286d |  | 2,072,834 | Adm. Financ. |  |
| 41 | 1.2 | **Producto 2: Interceptor construido** |  | 1125d | 2017-08-04 | 2021-11-25 |  | 286d |  | 59,888,714 |  |  |
| 42 | 1.2.1 | **LPI_1. Contratación de firma para el diseño y construcción de obras** |  | 800d | 2018-07-03 | 2021-07-26 |  | 374d |  | 55,452,508 |  |  |
| 43 | 1.2.1.1 | **Ejecución del contrato** |  | 800d | 2018-07-03 | 2021-07-26 |  | 374d |  | 55,452,508 |  |  |
| 44 | 1.2.1.1.1 | Elaboración del diseño final |  | 300d | 2018-07-03 | 2019-08-26 | 23SS | 374d | 0d |  | Contratista |  |
| 45 | 1.2.1.1.2 | Diseño del interceptor elaborado | milestone | 0d | 2019-08-26 | 2019-08-26 | 44 | 874d |  |  |  |  |
| 46 | 1.2.1.1.3 | Construcción del interceptor |  | 740d | 2018-09-25 | 2021-07-26 | 25SS | 374d | 0d |  | Contratista |  |
| 47 | 1.2.1.1.4 | Interceptor construido | milestone | 0d | 2021-07-26 | 2021-07-26 | 46 | 374d |  |  |  |  |
| 48 | 1.2.1.1.1 | **Pagos** |  | 800d | 2018-07-03 | 2021-07-26 |  | 374d |  | 55,452,508 |  |  |
| 49 | 1.2.1.1.1.1 | Pagos BID |  | 800d | 2018-07-03 | 2021-07-26 | 44SS | 374d | 0d | 10,000,000 | Adm. Financ. |  |
| 50 | 1.2.1.1.1.2 | Pagos AECID |  | 800d | 2018-07-03 | 2021-07-26 | 49SS | 374d | 0d | 25,000,000 | Adm. Financ. |  |
| 51 | 1.2.1.1.1.3 | Pago CL |  | 800d | 2018-07-03 | 2021-07-26 | 50SS | 374d |  | 20,452,508 | Adm. Financ. |  |

| ID | WBS | Task | Type | Duration | Start | Finish | Predecessors | Total slack | Free slack | Cost | Text5 |
| --- | --- | --- | --- | --- | --- | --- | --- | --- | --- | --- | --- |
| 52 | 1.2.2 | **SBCC_7. Contratación de firma consultora para la supervisión de diseños y obras** |  | 1125d | 2017-08-04 | 2021-11-25 |  | 286d |  | 4,436,206 |  |
| 53 | 1.2.2.1 | **Ejecución del contrato** |  | 1125d | 2017-08-04 | 2021-11-25 |  | 286d |  | 4,436,206 |  |
| 54 | 1.2.2.1.1 | Pagos BID |  | 1125d | 2017-08-04 | 2021-11-25 | 39SS | 286d | 0d | 3,550,463 | Adm. Financ. |
| 55 | 1.2.2.1.2 | Pagos CL |  | 1125d | 2017-08-04 | 2021-11-25 | 54SS | 286d |  | 885,743 | Adm. Financ. |
| 56 | 1.3 | **Producto 3: Colectoras construidas, rehabilitadas y/o ampliadas** |  | 1805d | 2016-02-01 | 2022-12-30 |  | 0d |  | 147,193,289 |  |
| 57 | 1.3.1 | **Colectoras construidas en las cuencas de la muestra: Prudente, Aguacate y Bernardino** |  | 910d | 2017-08-04 | 2021-01-28 |  | 501d |  | 52,039,011 |  |
| 58 | 1.3.1.1 | **LPI_1. Contratación de firma para el diseño y construcción de obras** |  | 650d | 2018-07-03 | 2020-12-28 |  | 524d |  | 48,184,269 |  |
| 59 | 1.3.1.1.1 | **Cuenca de Prudente** |  | 650d | 2018-07-03 | 2020-12-28 |  | 524d |  | 12,092,629 |  |
| 60 | 1.3.1.1.1.1 | **Ejecución del contrato** |  | 650d | 2018-07-03 | 2020-12-28 |  | 524d |  | 12,092,629 |  |
| 61 | 1.3.1.1.1.1.1 | Elaboración del diseño final |  | 200d | 2018-07-03 | 2019-04-08 | 44SS | 524d | 0d |  | Contratista |
| 62 | 1.3.1.1.1.1.2 | Diseño de las colectoras elaborado | milestone | 0d | 2019-04-08 | 2019-04-08 | 61 | 524d | 0d |  |  |
| 63 | 1.3.1.1.1.1.3 | Construcción de las colectoras |  | 450d | 2019-04-09 | 2020-12-28 | 62 | 524d | 0d |  | Contratista |
| 64 | 1.3.1.1.1.1.4 | Colectoras construidas | milestone | 0d | 2020-12-28 | 2020-12-28 | 63 | 524d |  |  |  |
| 65 | 1.3.1.1.1.1.5 | **Pagos** |  | 450d | 2018-07-03 | 2020-03-23 |  | 724d |  | 12,092,629 |  |
| 66 | 1.3.1.1.1.1.5.1 | Pagos BID |  | 450d | 2018-07-03 | 2020-03-23 | 61SS | 724d | 0d | 3,691,589 | Adm. Financ. |
| 67 | 1.3.1.1.1.1.5.2 | Pagos BCIE |  | 450d | 2018-07-03 | 2020-03-23 | 66SS | 724d | 0d | 7,609,934 | Adm. Financ. |
| 68 | 1.3.1.1.1.1.5.3 | Pagos CL |  | 450d | 2018-07-03 | 2020-03-23 | 67SS | 724d |  | 791,106 | Adm. Financ. |
| 69 | 1.3.1.1.2 | **Cuenca de Aguacate** |  | 650d | 2018-07-03 | 2020-12-28 |  | 524d |  | 17,778,590 |  |
| 70 | 1.3.1.1.2.1 | **Ejecución del contrato** |  | 650d | 2018-07-03 | 2020-12-28 |  | 524d |  | 17,778,590 |  |
| 71 | 1.3.1.1.2.1.1 | Elaboración del diseño final |  | 200d | 2018-07-03 | 2019-04-08 | 61SS | 524d | 0d |  | Contratista |
| 72 | 1.3.1.1.2.1.2 | Diseño de las colectoras elaborado | milestone | 0d | 2019-04-08 | 2019-04-08 | 71 | 524d | 0d |  |  |
| 73 | 1.3.1.1.2.1.3 | Construcción de las colectoras |  | 450d | 2019-04-09 | 2020-12-28 | 72 | 524d | 0d |  | Contratista |
| 74 | 1.3.1.1.2.1.4 | Colectoras construidas | milestone | 0d | 2020-12-28 | 2020-12-28 | 73 | 524d |  |  |  |
| 75 | 1.3.1.1.2.1.5 | **Pagos** |  | 650d | 2018-07-03 | 2020-12-28 |  | 524d |  | 17,778,590 |  |
| 76 | 1.3.1.1.2.1.5.1 | Pagos BID |  | 650d | 2018-07-03 | 2020-12-28 | 71SS | 524d | 0d | 4,861,845 | Adm. Financ. |
| 77 | 1.3.1.1.2.1.5.2 | Pagos BCIE |  | 650d | 2018-07-03 | 2020-12-28 | 76SS | 524d | 0d | 11,753,660 | Adm. Financ. |
| 78 | 1.3.1.1.2.1.5.3 | Pagos CL |  | 650d | 2018-07-03 | 2020-12-28 | 77SS | 524d |  | 1,163,085 | Adm. Financ. |

Notes:
- 59: Corresponde a un lote dentro del mismo llamado de LPI desarrollado para la PTAR. / Mismo tiempo de ejecución para colectoras, redes y conexiones intradomiciliarias

| ID | WBS | Task | Type | Duration | Start | Finish | Predecessors | Total slack | Free slack | Cost | Text5 |
| --- | --- | --- | --- | --- | --- | --- | --- | --- | --- | --- | --- |
| 79 | 1.3.1.1.3 | **Cuenca de Bernardino** |  | 645d | 2018-07-03 | 2020-12-21 |  | 529d |  | 18,313,050 |  |
| 80 | 1.3.1.1.3.1 | Elaboración del diseño final |  | 200d | 2018-07-03 | 2019-04-08 | 71SS | 529d | 0d |  | Contratista |
| 81 | 1.3.1.1.3.2 | Diseño de las colectoras elaborado | milestone | 0d | 2019-04-08 | 2019-04-08 | 80 | 529d | 0d |  |  |
| 82 | 1.3.1.1.3.3 | Construcción de las colectoras |  | 430d | 2019-04-30 | 2020-12-21 | 81FS+15d | 529d | 0d |  | Contratista |
| 83 | 1.3.1.1.3.4 | Colectoras construidas | milestone | 0d | 2020-12-21 | 2020-12-21 | 82 | 529d |  |  |  |
| 84 | 1.3.1.1.3.5 | **Pagos** |  | 645d | 2018-07-03 | 2020-12-21 |  | 529d |  | 18,313,050 |  |
| 85 | 1.3.1.1.3.5.1 | Pagos BID |  | 645d | 2018-07-03 | 2020-12-21 | 80SS | 529d | 0d | 3,000,000 | Adm. Financ. |
| 86 | 1.3.1.1.3.5.2 | Pagos BEI |  | 645d | 2018-07-03 | 2020-12-21 | 85SS | 529d | 0d | 14,115,000 | Adm. Financ. |
| 87 | 1.3.1.1.3.5.3 | Pagos CL |  | 645d | 2018-07-03 | 2020-12-21 | 86SS | 529d |  | 1,198,050 | Adm. Financ. |
| 88 | 1.3.1.2 | **SBCC_6. Contratación de firma consultora para la supervisión de diseños y obras** |  | 910d | 2017-08-04 | 2021-01-28 |  | 501d |  | 3,854,742 |  |
| 89 | 1.3.1.2.1 | **Ejecución del contrato** |  | 910d | 2017-08-04 | 2021-01-28 |  | 501d |  | 3,854,742 |  |
| 90 | 1.3.1.2.1.1 | Pagos BID |  | 910d | 2017-08-04 | 2021-01-28 | 54SS | 501d | 0d | 3,085,099 | Adm. Financ. |
| 91 | 1.3.1.2.1.2 | Pagos CL |  | 910d | 2017-08-04 | 2021-01-28 | 90SS | 501d |  | 769,643 | Adm. Financ. |
| 92 | 1.3.2 | **Colectoras construidas en las cuencas de Martín Sánchez I y II, Rodeo, Cruce y Puerto Caimito** |  | 1565d | 2016-02-01 | 2022-01-28 |  | 0d |  | 59,947,328 |  |
| 93 | 1.3.2.1 | **LPI_2. Contratación de firma para el diseño y construcción de obras** |  | 1076d | 2017-11-14 | 2021-12-28 |  | 263d |  | 55,506,785 |  |
| 94 | 1.3.2.1.1 | Etapa previa |  | 65d | 2017-11-14 | 2018-02-12 | 135FS+36d | 263d | 0d |  | PM |
| 95 | 1.3.2.1.2 | Etapa de contratación |  | 135d | 2018-02-13 | 2018-08-20 | 94 | 263d | 0d |  | PM y Adm. Pry |
| 96 | 1.3.2.1.3 | Formalización del contrato |  | 90d | 2018-08-21 | 2018-12-24 | 95 | 263d | 0d |  | BID |
| 97 | 1.3.2.1.4 | **Ejecución del contrato** |  | 785d | 2018-12-26 | 2021-12-28 |  | 263d |  | 55,506,785 |  |
| 98 | 1.3.2.1.4.1 | **Cuenca de Martín Sánchez I** |  | 785d | 2018-12-26 | 2021-12-28 |  | 263d |  | 24,054,135 |  |
| 99 | 1.3.2.1.4.1.1 | Elaboración del diseño final |  | 220d | 2018-12-26 | 2019-10-29 | 96FS+1d | 263d | 0d |  | Contratista |
| 100 | 1.3.2.1.4.1.2 | Diseño de las colectoras elaborado | milestone | 0d | 2019-10-29 | 2019-10-29 | 99 | 828d |  |  |  |
| 101 | 1.3.2.1.4.1.3 | Construcción de las colectoras |  | 720d | 2019-03-27 | 2021-12-28 | 99SS+65d | 263d | 0d |  | Contratista |
| 102 | 1.3.2.1.4.1.4 | Colectoras construidas | milestone | 0d | 2021-12-28 | 2021-12-28 | 101 | 263d |  |  |  |

| ID | WBS | Task | Type | Duration | Start | Finish | Predecessors | Total slack | Free slack | Cost | Text5 |
| --- | --- | --- | --- | --- | --- | --- | --- | --- | --- | --- | --- |
| 103 | 1.3.2.1.4.1.5 | **Pagos** |  | 785d | 2018-12-26 | 2021-12-28 |  | 263d |  | 24,054,135 |  |
| 104 | 1.3.2.1.4.1.5.1 | Pagos BID |  | 785d | 2018-12-26 | 2021-12-28 | 99SS | 263d | 0d | 22,480,500 | Adm. Financ. |
| 105 | 1.3.2.1.4.1.5.2 | Pagos CL |  | 785d | 2018-12-26 | 2021-12-28 | 104SS | 263d |  | 1,573,635 | Adm. Financ. |
| 106 | 1.3.2.1.4.2 | **Cuenca de Martín Sánchez II** |  | 730d | 2019-03-13 | 2021-12-28 |  | 263d |  | 7,190,400 |  |
| 107 | 1.3.2.1.4.2.1 | Elaboración del diseño final |  | 200d | 2019-03-13 | 2019-12-17 | 99SS+55d | 263d | 0d |  | Contratista |
| 108 | 1.3.2.1.4.2.2 | Diseño de las colectoras elaborado | milestone | 0d | 2019-12-17 | 2019-12-17 | 107 | 263d | 0d |  |  |
| 109 | 1.3.2.1.4.2.3 | Construcción de las colectoras |  | 530d | 2019-12-18 | 2021-12-28 | 108 | 263d | 0d |  | Contratista |
| 110 | 1.3.2.1.4.2.4 | Colectoras construidas | milestone | 0d | 2021-12-28 | 2021-12-28 | 109 | 263d |  |  |  |
| 111 | 1.3.2.1.4.2.5 | **Pagos** |  | 730d | 2019-03-13 | 2021-12-28 |  | 263d |  | 7,190,400 |  |
| 112 | 1.3.2.1.4.2.5.1 | Pagos BID |  | 730d | 2019-03-13 | 2021-12-28 | 107SS | 263d | 0d | 6,720,000 | Adm. Financ. |
| 113 | 1.3.2.1.4.2.5.2 | Pagos CL |  | 730d | 2019-03-13 | 2021-12-28 | 112SS | 263d |  | 470,400 | Adm. Financ. |
| 114 | 1.3.2.1.4.3 | **Cuenca de Cruce y Puerto Caimito** |  | 450d | 2018-12-26 | 2020-09-15 |  | 428d |  | 15,498,950 |  |
| 115 | 1.3.2.1.4.3.1 | Elaboración del diseño final |  | 120d | 2018-12-26 | 2019-06-11 | 99SS | 428d | 0d |  | Contratista |
| 116 | 1.3.2.1.4.3.2 | Diseño de las colectoras elaborado | milestone | 0d | 2019-06-11 | 2019-06-11 | 115 | 928d |  |  |  |
| 117 | 1.3.2.1.4.3.3 | Construcción de las colectoras |  | 330d | 2019-03-27 | 2020-06-30 | 115SS+65d | 653d | 0d |  | Contratista |
| 118 | 1.3.2.1.4.3.4 | Colectoras construidas | milestone | 0d | 2020-06-30 | 2020-06-30 | 117 | 653d |  |  |  |
| 119 | 1.3.2.1.4.3.5 | **Pagos** |  | 450d | 2018-12-26 | 2020-09-15 |  | 598d |  | 15,498,950 |  |
| 120 | 1.3.2.1.4.3.5.1 | Pagos BEI |  | 450d | 2018-12-26 | 2020-09-15 | 115SS | 598d | 0d | 9,090,000 | Adm. Financ. |
| 121 | 1.3.2.1.4.3.5.2 | Pagos CL |  | 450d | 2018-12-26 | 2020-09-15 | 120SS | 598d |  | 6,408,950 | Adm. Financ. |
| 122 | 1.3.2.1.4.4 | **Cuenca de Rodeo** |  | 620d | 2018-12-26 | 2021-05-11 |  | 428d |  | 8,763,300 |  |
| 123 | 1.3.2.1.4.4.1 | Elaboración del diseño final |  | 200d | 2018-12-26 | 2019-10-01 | 115SS | 428d | 0d |  | Contratista |
| 124 | 1.3.2.1.4.4.2 | Diseño de las colectoras elaborado | milestone | 0d | 2019-10-01 | 2019-10-01 | 123 | 848d |  |  |  |
| 125 | 1.3.2.1.4.4.3 | Construcción de las colectoras |  | 555d | 2019-03-27 | 2021-05-11 | 123SS+65d | 428d | 0d |  | Contratista |
| 126 | 1.3.2.1.4.4.4 | Colectoras construidas | milestone | 0d | 2021-05-11 | 2021-05-11 | 125 | 428d |  |  |  |

| ID | WBS | Task | Type | Duration | Start | Finish | Predecessors | Total slack | Free slack | Cost | Text5 |
| --- | --- | --- | --- | --- | --- | --- | --- | --- | --- | --- | --- |
| 127 | 1.3.2.1.4.4.5 | **Pagos** |  | 620d | 2018-12-26 | 2021-05-11 |  | 428d |  | 8,763,300 |  |
| 128 | 1.3.2.1.4.4.5.1 | Pagos BID |  | 620d | 2018-12-26 | 2021-05-11 | 123SS | 428d | 0d | 4,759,173 | Adm. Financ. |
| 129 | 1.3.2.1.4.4.5.2 | Pagos CAF |  | 620d | 2018-12-26 | 2021-05-11 | 128SS | 428d | 0d | 3,430,827 | Adm. Financ. |
| 130 | 1.3.2.1.4.4.5.3 | Pagos CL |  | 620d | 2018-12-26 | 2021-05-11 | 129SS | 428d |  | 573,300 | Adm. Financ. |
| 131 | 1.3.2.2 | **SBCC_7. Contratación de firma consultora para la supervisión de diseños y obras** |  | 1565d | 2016-02-01 | 2022-01-28 |  | 0d |  | 4,440,543 |  |
| 132 | 1.3.2.2.1 | Etapa previa |  | 160d | 2016-02-01 | 2016-09-09 | 33SS+20d | 0d |  |  | Adm. Pry |
| 133 | 1.3.2.2.2 | Etapa de Expresión de interés |  | 45d | 2016-09-12 | 2016-11-11 | 132 | 240d | 0d |  | Gte. Leg. Y Contr. |
| 134 | 1.3.2.2.3 | Etapa de contratación |  | 160d | 2016-11-14 | 2017-06-23 | 133 | 240d | 0d |  | Adm. Pry |
| 135 | 1.3.2.2.4 | Formalización del contrato |  | 65d | 2017-06-26 | 2017-09-22 | 134 | 240d | 0d |  | Gte. Leg. Y Contr. |
| 136 | 1.3.2.2.5 | Ejecución del contrato |  | 1135d | 2017-09-25 | 2022-01-28 | 135 | 240d | 0d |  | PM |
| 137 | 1.3.2.2.6 | **Pagos** |  | 1135d | 2017-09-25 | 2022-01-28 |  | 240d |  | 4,440,543 |  |
| 138 | 1.3.2.2.6.1 | Pagos BID |  | 1135d | 2017-09-25 | 2022-01-28 | 136SS | 240d | 0d | 989,202 | Adm. Financ. |
| 139 | 1.3.2.2.6.2 | Pagos CL |  | 1135d | 2017-09-25 | 2022-01-28 | 138SS | 240d |  | 3,451,341 | Adm. Financ. |
| 140 | 1.3.3 | **Colectoras construidas en las cuencas de Caimito I, Caimito II y Punta Piedras** |  | 1805d | 2016-02-01 | 2022-12-30 |  | 0d |  | 35,206,950 |  |
| 141 | 1.3.3.1 | **LPI_3. Contratación de firma para el diseño y construcción de obras** |  | 1281d | 2018-01-03 | 2022-11-30 |  | 22d |  | 32,599,029 |  |
| 142 | 1.3.3.1.1 | Etapa previa |  | 65d | 2018-01-03 | 2018-04-03 | 173FS+72d | 22d | 0d |  | PM |
| 143 | 1.3.3.1.2 | Etapa de contratación |  | 135d | 2018-04-04 | 2018-10-09 | 142 | 22d | 0d |  | PM y Adm. Pry |
| 144 | 1.3.3.1.3 | Formalización del contrato |  | 90d | 2018-10-10 | 2019-02-12 | 143 | 22d | 0d |  | BID |
| 145 | 1.3.3.1.4 | **Ejecución del contrato** |  | 991d | 2019-02-13 | 2022-11-30 |  | 22d |  | 32,599,029 |  |
| 146 | 1.3.3.1.4.1 | **Cuenca de Caimito I** |  | 955d | 2019-02-13 | 2022-10-11 |  | 22d |  | 21,346,502 |  |
| 147 | 1.3.3.1.4.1.1 | Elaboración del diseño final |  | 220d | 2019-02-13 | 2019-12-17 | 144 | 22d | 0d |  | Contratista |
| 148 | 1.3.3.1.4.1.2 | Diseño de las colectoras elaborado | milestone | 0d | 2019-12-17 | 2019-12-17 | 147 | 793d |  |  |  |
| 149 | 1.3.3.1.4.1.3 | Construcción de las colectoras |  | 895d | 2019-05-08 | 2022-10-11 | 147SS+60d | 58d | 0d |  | Contratista |
| 150 | 1.3.3.1.4.1.4 | Colectoras construidas | milestone | 0d | 2022-10-11 | 2022-10-11 | 149 | 58d |  |  |  |

Notes:
- 132: En la programación del equipo se tenía definido el inicio al 14/11/2017

| ID | WBS | Task | Type | Duration | Start | Finish | Predecessors | Total slack | Free slack | Cost | Text5 |
| --- | --- | --- | --- | --- | --- | --- | --- | --- | --- | --- | --- |
| 151 | 1.3.3.1.4.1.5 | **Pagos** |  | 955d | 2019-02-13 | 2022-10-11 |  | 58d |  | 21,346,502 |  |
| 152 | 1.3.3.1.4.1.5.1 | Pagos BID |  | 955d | 2019-02-13 | 2022-10-11 | 147SS | 58d | 0d | 15,175,409 | Adm. Financ. |
| 153 | 1.3.3.1.4.1.5.2 | Pagos CL |  | 955d | 2019-02-13 | 2022-10-11 | 152SS | 58d |  | 6,171,093 | Adm. Financ. |
| 154 | 1.3.3.1.4.2 | **Cuenca de Caimito II** |  | 990d | 2019-02-13 | 2022-11-29 |  | 22d |  | 2,471,700 |  |
| 155 | 1.3.3.1.4.2.1 | Elaboración del diseño final |  | 220d | 2019-02-13 | 2019-12-17 | 147SS | 22d | 0d |  | Contratista |
| 156 | 1.3.3.1.4.2.2 | Diseño de las colectoras elaborado | milestone | 0d | 2019-12-17 | 2019-12-17 | 155 | 793d |  |  |  |
| 157 | 1.3.3.1.4.2.3 | Construcción de las colectoras |  | 930d | 2019-05-08 | 2022-11-29 | 155SS+60d | 23d | 0d |  | Contratista |
| 158 | 1.3.3.1.4.2.4 | Colectoras construidas | milestone | 0d | 2022-11-29 | 2022-11-29 | 157 | 23d |  |  |  |
| 159 | 1.3.3.1.4.2.5 | **Pagos** |  | 990d | 2019-02-13 | 2022-11-29 |  | 23d |  | 2,471,700 |  |
| 160 | 1.3.3.1.4.2.5.1 | Pagos BID |  | 990d | 2019-02-13 | 2022-11-29 | 155SS | 23d | 0d | 2,310,000 | Adm. Financ. |
| 161 | 1.3.3.1.4.2.5.2 | Pagos CL |  | 990d | 2019-02-13 | 2022-11-29 | 160SS | 23d |  | 161,700 | Adm. Financ. |
| 162 | 1.3.3.1.4.3 | **Cuenca de Punta Piedras** |  | 406d | 2021-05-12 | 2022-11-30 |  | 22d |  | 8,780,827 |  |
| 163 | 1.3.3.1.4.3.1 | Elaboración del diseño final |  | 120d | 2021-05-12 | 2021-10-26 | 155SS+585d | 22d | 0d |  | Contratista |
| 164 | 1.3.3.1.4.3.2 | Diseño de las colectoras elaborado | milestone | 0d | 2021-10-26 | 2021-10-26 | 163 | 308d |  |  |  |
| 165 | 1.3.3.1.4.3.3 | Construcción de las colectoras |  | 286d | 2021-10-27 | 2022-11-30 | 163 | 22d | 0d |  | Contratista |
| 166 | 1.3.3.1.4.3.4 | Colectoras construidas | milestone | 0d | 2022-11-30 | 2022-11-30 | 165 | 22d |  |  |  |
| 167 | 1.3.3.1.4.3.5 | **Pagos** |  | 405d | 2021-05-12 | 2022-11-29 |  | 23d |  | 8,780,827 |  |
| 168 | 1.3.3.1.4.3.5.1 | Pagos CL |  | 405d | 2021-05-12 | 2022-11-29 | 163SS | 23d |  | 8,780,827 | Adm. Financ. |
| 169 | 1.3.3.2 | **SBCC_8. Contratación de firma consultora para la supervisión de diseños y obras** |  | 1805d | 2016-02-01 | 2022-12-30 |  | 0d |  | 2,607,921 |  |
| 170 | 1.3.3.2.1 | Etapa previa |  | 40d | 2016-02-01 | 2016-03-25 | 132SS | 0d |  |  | Adm. Pry |
| 171 | 1.3.3.2.2 | Expresión de interés |  | 60d | 2016-03-28 | 2016-06-17 | 170 | 1705d |  |  | Gte. Leg. Y Contr. |
| 172 | 1.3.3.2.3 | Etapa de contratación |  | 200d | 2016-03-28 | 2016-12-30 | 170 | 0d |  |  | Adm. Pry |
| 173 | 1.3.3.2.4 | Formalización del contrato |  | 190d | 2017-01-02 | 2017-09-22 | 172 | 0d |  |  | Gte. Leg. Y Contr. |
| 174 | 1.3.3.2.5 | **Ejecución de contrato** |  | 1375d | 2017-09-25 | 2022-12-30 |  | 0d |  | 2,607,921 |  |
| 175 | 1.3.3.2.5.1 | Pagos BID |  | 1375d | 2017-09-25 | 2022-12-30 | 173 | 0d |  | 580,956 | Adm. Financ. |
| 176 | 1.3.3.2.5.2 | Pagos CL |  | 1375d | 2017-09-25 | 2022-12-30 | 175SS | 0d |  | 2,026,965 | Adm. Financ. |

| ID | WBS | Task | Type | Duration | Start | Finish | Predecessors | Total slack | Free slack | Cost | Text5 | Text1 |
| --- | --- | --- | --- | --- | --- | --- | --- | --- | --- | --- | --- | --- |
| 177 | 1.4 | **Producto 4: Redes de alcantarillado construidas** |  | 1411d | 2017-08-04 | 2022-12-30 |  | 0d |  | 201,712,207 |  |  |
| 178 | 1.4.1 | **Redes construidas en las cuencas de la muestra: Prudente, Aguacate y Bernardino** |  | 910d | 2017-08-04 | 2021-01-28 |  | 501d |  | 38,514,457 |  |  |
| 179 | 1.4.1.1 | **LPI_1. Contratación de firma para el diseño y construcción de obras** |  | 650d | 2018-07-03 | 2020-12-28 |  | 524d |  | 35,661,535 |  |  |
| 180 | 1.4.1.1.1 | **Cuenca de Prudente** |  | 650d | 2018-07-03 | 2020-12-28 |  | 524d |  | 9,544,607 |  |  |
| 181 | 1.4.1.1.1.1 | **Ejecución del contrato** |  | 650d | 2018-07-03 | 2020-12-28 |  | 524d |  | 9,544,607 |  |  |
| 182 | 1.4.1.1.1.1.1 | Elaboración del diseño final |  | 200d | 2018-07-03 | 2019-04-08 | 61SS | 524d | 0d |  | Contratista |  |
| 183 | 1.4.1.1.1.1.2 | Diseño de redes elaborado | milestone | 0d | 2019-04-08 | 2019-04-08 | 182 | 524d | 0d |  |  |  |
| 184 | 1.4.1.1.1.1.3 | Construcción de las redes |  | 450d | 2019-04-09 | 2020-12-28 | 183 | 524d | 0d |  | Contratista |  |
| 185 | 1.4.1.1.1.1.4 | Redes construidas | milestone | 0d | 2020-12-28 | 2020-12-28 | 184 | 524d |  |  |  |  |
| 186 | 1.4.1.1.1.1.5 | **Pagos** |  | 650d | 2018-07-03 | 2020-12-28 |  | 524d |  | 9,544,607 |  | Contratista |
| 187 | 1.4.1.1.1.1.5.1 | Pagos BCIE |  | 650d | 2018-07-03 | 2020-12-28 | 182SS | 524d | 0d | 8,920,193 | Adm. Financ. |  |
| 188 | 1.4.1.1.1.1.5.2 | Pagos CL |  | 650d | 2018-07-03 | 2020-12-28 | 187SS | 524d |  | 624,414 | Adm. Financ. |  |
| 189 | 1.4.1.1.2 | **Cuenca de Aguacate** |  | 650d | 2018-07-03 | 2020-12-28 |  | 524d |  | 6,616,692 |  |  |
| 190 | 1.4.1.1.2.1 | **Ejecución del contrato** |  | 650d | 2018-07-03 | 2020-12-28 |  | 524d |  | 6,616,692 |  |  |
| 191 | 1.4.1.1.2.1.1 | Elaboración del diseño final |  | 200d | 2018-07-03 | 2019-04-08 | 71SS | 524d | 0d |  | Contratista |  |
| 192 | 1.4.1.1.2.1.2 | Diseño de redes elaborado | milestone | 0d | 2019-04-08 | 2019-04-08 | 191 | 524d | 0d |  |  |  |
| 193 | 1.4.1.1.2.1.3 | Construcción de las redes |  | 450d | 2019-04-09 | 2020-12-28 | 192 | 524d | 0d |  | Contratista |  |
| 194 | 1.4.1.1.2.1.4 | Redes construidas | milestone | 0d | 2020-12-28 | 2020-12-28 | 193 | 524d |  |  |  |  |
| 195 | 1.4.1.1.2.1.5 | **Pagos** |  | 650d | 2018-07-03 | 2020-12-28 |  | 524d |  | 6,616,692 |  |  |
| 196 | 1.4.1.1.2.1.5.1 | Pagos BCIE |  | 650d | 2018-07-03 | 2020-12-28 | 191SS | 524d | 0d | 6,183,824 | Adm. Financ. |  |
| 197 | 1.4.1.1.2.1.5.2 | Pagos CL |  | 650d | 2018-07-03 | 2020-12-28 | 196SS | 524d |  | 432,868 | Adm. Financ. |  |
| 198 | 1.4.1.1.3 | **Cuenca de Bernardino** |  | 645d | 2018-07-03 | 2020-12-21 |  | 529d |  | 19,500,236 |  |  |
| 199 | 1.4.1.1.3.1 | Elaboración del diseño final |  | 200d | 2018-07-03 | 2019-04-08 | 80SS | 529d | 0d |  | Contratista |  |
| 200 | 1.4.1.1.3.2 | Diseño de las redes elaborado | milestone | 0d | 2019-04-08 | 2019-04-08 | 199 | 974d |  |  |  |  |
| 201 | 1.4.1.1.3.3 | Construcción de las redes |  | 430d | 2019-04-30 | 2020-12-21 | 82SS | 529d | 0d |  | Contratista |  |
| 202 | 1.4.1.1.3.4 | Redes construidas | milestone | 0d | 2020-12-21 | 2020-12-21 | 201 | 529d |  |  |  |  |

Notes:
- 180: Corresponde a un lote dentro del mismo llamado de LPI desarrollado para la PTAR. / Mismo tiempo de ejecución para colectoras, redes y conexiones intradomiciliarias

| ID | WBS | Task | Type | Duration | Start | Finish | Predecessors | Total slack | Free slack | Cost | Text5 |
| --- | --- | --- | --- | --- | --- | --- | --- | --- | --- | --- | --- |
| 203 | 1.4.1.1.3.5 | **Pagos** |  | 645d | 2018-07-03 | 2020-12-21 |  | 529d |  | 19,500,236 |  |
| 204 | 1.4.1.1.3.5.1 | Pagos BEI |  | 645d | 2018-07-03 | 2020-12-21 | 199SS | 529d | 0d | 18,224,520 | Adm. Financ. |
| 205 | 1.4.1.1.3.5.2 | Pagos CL |  | 645d | 2018-07-03 | 2020-12-21 | 204SS | 529d |  | 1,275,716 | Adm. Financ. |
| 206 | 1.4.1.2 | **SBCC_6. Contratación de firma consultora para la supervisión de diseños y obras** |  | 910d | 2017-08-04 | 2021-01-28 |  | 501d |  | 2,852,922 |  |
| 207 | 1.4.1.2.1 | **Ejecución del contrato** |  | 910d | 2017-08-04 | 2021-01-28 |  | 501d |  | 2,852,922 |  |
| 208 | 1.4.1.2.1.1 | Pagos BID |  | 910d | 2017-08-04 | 2021-01-28 | 90SS | 501d | 0d | 2,283,304 | Adm. Financ. |
| 209 | 1.4.1.2.1.2 | Pagos CL |  | 910d | 2017-08-04 | 2021-01-28 | 208SS | 501d |  | 569,618 | Adm. Financ. |
| 210 | 1.4.2 | **Redes construidas en las cuencas de Martín Sánchez I y II, Rodeo y Puerto Caimito** |  | 1135d | 2017-09-25 | 2022-01-28 |  | 240d |  | 96,921,737 |  |
| 211 | 1.4.2.1 | **LPI_2. Contratación de firma para el diseño y construcción de obras** |  | 785d | 2018-12-26 | 2021-12-28 |  | 263d |  | 89,742,349 |  |
| 212 | 1.4.2.1.1 | **Cuenca de Martín Sánchez I** |  | 785d | 2018-12-26 | 2021-12-28 |  | 263d |  | 42,740,994 |  |
| 213 | 1.4.2.1.1.1 | **Ejecución del contrato** |  | 785d | 2018-12-26 | 2021-12-28 |  | 263d |  | 42,740,994 |  |
| 214 | 1.4.2.1.1.1.1 | Elaboración del diseño final |  | 220d | 2018-12-26 | 2019-10-29 | 99SS | 263d | 0d |  | Contratista |
| 215 | 1.4.2.1.1.1.2 | Diseño de las redes elaborado | milestone | 0d | 2019-10-29 | 2019-10-29 | 214 | 828d |  |  |  |
| 216 | 1.4.2.1.1.1.3 | Construcción de las colectoras |  | 720d | 2019-03-27 | 2021-12-28 | 214SS+65d | 263d | 0d |  | Contratista |
| 217 | 1.4.2.1.1.1.4 | Redes construidas | milestone | 0d | 2021-12-28 | 2021-12-28 | 216 | 263d |  |  |  |
| 218 | 1.4.2.1.1.1.5 | **Pagos** |  | 785d | 2018-12-26 | 2021-12-28 |  | 263d |  | 42,740,994 |  |
| 219 | 1.4.2.1.1.1.5.1 | Pagos CAF |  | 785d | 2018-12-26 | 2021-12-28 | 214SS | 263d | 0d | 11,725,700 | Adm. Financ. |
| 220 | 1.4.2.1.1.1.5.2 | Pagos BCIE |  | 785d | 2018-12-26 | 2021-12-28 | 219SS | 263d | 0d | 24,242,946 | Adm. Financ. |
| 221 | 1.4.2.1.1.1.5.3 | Pagos BEI |  | 785d | 2018-12-26 | 2021-12-28 | 220SS | 263d | 0d | 1,388,061 | Adm. Financ. |
| 222 | 1.4.2.1.1.1.5.4 | Pagos CL |  | 785d | 2018-12-26 | 2021-12-28 | 221SS | 263d |  | 5,384,287 | Adm. Financ. |
| 223 | 1.4.2.1.2 | **Cuenca de Martín Sánchez II** |  | 730d | 2019-03-13 | 2021-12-28 |  | 263d |  | 21,467,262 |  |
| 224 | 1.4.2.1.2.1 | **Ejecución del contrato** |  | 730d | 2019-03-13 | 2021-12-28 |  | 263d |  | 21,467,262 |  |
| 225 | 1.4.2.1.2.1.1 | Elaboración del diseño final |  | 200d | 2019-03-13 | 2019-12-17 | 214SS+55d | 263d | 0d |  | Contratista |
| 226 | 1.4.2.1.2.1.2 | Diseño de las redes elaborado | milestone | 0d | 2019-12-17 | 2019-12-17 | 225 | 793d |  |  |  |
| 227 | 1.4.2.1.2.1.3 | Construcción de las colectoras |  | 530d | 2019-12-18 | 2021-12-28 | 225 | 263d | 0d |  | Contratista |
| 228 | 1.4.2.1.2.1.4 | Redes construidas | milestone | 0d | 2021-12-28 | 2021-12-28 | 227 | 263d |  |  |  |

| ID | WBS | Task | Type | Duration | Start | Finish | Predecessors | Total slack | Free slack | Cost | Text5 |
| --- | --- | --- | --- | --- | --- | --- | --- | --- | --- | --- | --- |
| 229 | 1.4.2.1.2.1.5 | **Pagos** |  | 730d | 2019-03-13 | 2021-12-28 |  | 263d |  | 21,467,262 |  |
| 230 | 1.4.2.1.2.1.5.1 | Pagos CAF |  | 730d | 2019-03-13 | 2021-12-28 | 225SS | 263d | 0d | 8,000,000 | Adm. Financ. |
| 231 | 1.4.2.1.2.1.5.2 | Pagos BCIE |  | 730d | 2019-03-13 | 2021-12-28 | 230SS | 263d | 0d | 12,062,862 | Adm. Financ. |
| 232 | 1.4.2.1.2.1.5.3 | Pagos CL |  | 730d | 2019-03-13 | 2021-12-28 | 231SS | 263d |  | 1,404,400 | Adm. Financ. |
| 233 | 1.4.2.1.4 | **Cuenca de Puerto Caimito** |  | 450d | 2018-12-26 | 2020-09-15 |  | 598d |  | 7,257,165 |  |
| 234 | 1.4.2.1.4.1 | **Ejecución del contrato** |  | 450d | 2018-12-26 | 2020-09-15 |  | 598d |  | 7,257,165 |  |
| 235 | 1.4.2.1.4.1.1 | Elaboración del diseño final |  | 120d | 2018-12-26 | 2019-06-11 | 115SS | 598d | 0d |  | Contratista |
| 236 | 1.4.2.1.4.1.2 | Diseño de las redes elaborado | milestone | 0d | 2019-06-11 | 2019-06-11 | 235 | 598d | 0d |  |  |
| 237 | 1.4.2.1.4.1.3 | Construcción de las colectoras |  | 330d | 2019-06-12 | 2020-09-15 | 236 | 598d | 0d |  | Contratista |
| 238 | 1.4.2.1.4.1.4 | Redes construidas | milestone | 0d | 2020-09-15 | 2020-09-15 | 237 | 598d |  |  |  |
| 239 | 1.4.2.1.4.1.5 | **Pagos** |  | 450d | 2018-12-26 | 2020-09-15 |  | 598d |  | 7,257,165 |  |
| 240 | 1.4.2.1.4.1.5.1 | Pagos CL |  | 450d | 2018-12-26 | 2020-09-15 | 235SS | 598d |  | 7,257,165 | Adm. Financ. |
| 241 | 1.4.2.1.3 | **Cuenca de Rodeo** |  | 620d | 2018-12-26 | 2021-05-11 |  | 428d |  | 18,276,928 |  |
| 242 | 1.4.2.1.3.1 | **Ejecución del contrato** |  | 620d | 2018-12-26 | 2021-05-11 |  | 428d |  | 18,276,928 |  |
| 243 | 1.4.2.1.3.1.1 | Elaboración del diseño final |  | 200d | 2018-12-26 | 2019-10-01 | 123SS | 428d | 0d |  | Contratista |
| 244 | 1.4.2.1.3.1.2 | Diseño de las redes elaborado | milestone | 0d | 2019-10-01 | 2019-10-01 | 243 | 848d |  |  |  |
| 245 | 1.4.2.1.3.1.3 | Construcción de las colectoras |  | 555d | 2019-03-27 | 2021-05-11 | 243SS+65d | 428d | 0d |  | Contratista |
| 246 | 1.4.2.1.3.1.4 | Redes construidas | milestone | 0d | 2021-05-11 | 2021-05-11 | 245 | 428d |  |  |  |
| 247 | 1.4.2.1.3.1.5 | **Pagos** |  | 620d | 2018-12-26 | 2021-05-11 |  | 428d |  | 18,276,928 |  |
| 248 | 1.4.2.1.3.1.5.1 | Pagos CAF |  | 620d | 2018-12-26 | 2021-05-11 | 243SS | 428d | 0d | 5,569,173 | Adm. Financ. |
| 249 | 1.4.2.1.3.1.5.2 | Pagos BCIE |  | 620d | 2018-12-26 | 2021-05-11 | 248SS | 428d | 0d | 11,512,068 | Adm. Financ. |
| 250 | 1.4.2.1.3.1.5.3 | Pagos CL |  | 620d | 2018-12-26 | 2021-05-11 | 249SS | 428d |  | 1,195,687 | Adm. Financ. |
| 251 | 1.4.2.2 | **SBCC_7. Contratación de firma consultora para la supervisión de diseños y obras** |  | 1135d | 2017-09-25 | 2022-01-28 |  | 240d |  | 7,179,388 |  |
| 252 | 1.4.2.2.1 | **Ejecución de contrato** |  | 1135d | 2017-09-25 | 2022-01-28 |  | 240d |  | 7,179,388 |  |
| 253 | 1.4.2.2.1.1 | Pagos BID |  | 1135d | 2017-09-25 | 2022-01-28 | 138SS | 240d | 0d | 1,599,323 | Adm. Financ. |
| 254 | 1.4.2.2.1.2 | Pagos CL |  | 1135d | 2017-09-25 | 2022-01-28 | 253SS | 240d |  | 5,580,065 | Adm. Financ. |

| ID | WBS | Task | Type | Duration | Start | Finish | Predecessors | Total slack | Free slack | Cost | Text5 |
| --- | --- | --- | --- | --- | --- | --- | --- | --- | --- | --- | --- |
| 255 | 1.4.3 | **Redes construidas en las cuencas de Caimito I y Caimito II** |  | 1375d | 2017-09-25 | 2022-12-30 |  | 0d |  | 66,276,013 |  |
| 256 | 1.4.3.1 | **LPI_3. Contratación de firma para el diseño y construcción de obras** |  | 990d | 2019-02-13 | 2022-11-29 |  | 23d |  | 61,366,679 |  |
| 257 | 1.4.3.1.1 | **Cuenca de Caimito I** |  | 955d | 2019-02-13 | 2022-10-11 |  | 58d |  | 19,443,713 |  |
| 258 | 1.4.3.1.1.1 | **Ejecución del contrato** |  | 955d | 2019-02-13 | 2022-10-11 |  | 58d |  | 19,443,713 |  |
| 259 | 1.4.3.1.1.1.1 | Elaboración del diseño final |  | 220d | 2019-02-13 | 2019-12-17 | 147SS | 58d | 0d |  | Contratista |
| 260 | 1.4.3.1.1.1.2 | Diseño de las redes elaborado | milestone | 0d | 2019-12-17 | 2019-12-17 | 259 | 793d |  |  |  |
| 261 | 1.4.3.1.1.1.3 | Construcción de las colectoras |  | 895d | 2019-05-08 | 2022-10-11 | 259SS+60d | 58d | 0d |  | Contratista |
| 262 | 1.4.3.1.1.1.4 | Redes construidas | milestone | 0d | 2022-10-11 | 2022-10-11 | 261 | 58d |  |  |  |
| 263 | 1.4.3.1.1.1.5 | **Pagos** |  | 955d | 2019-02-13 | 2022-10-11 |  | 58d |  | 19,443,713 |  |
| 264 | 1.4.3.1.1.1.5.1 | Pagos CL |  | 955d | 2019-02-13 | 2022-10-11 | 259SS | 58d | 0d | 19,443,713 | Adm. Financ. |
| 265 | 1.4.3.1.2 | **Cuenca de Caimito II** |  | 990d | 2019-02-13 | 2022-11-29 |  | 23d |  | 41,922,966 |  |
| 266 | 1.4.3.1.2.1 | **Ejecución del contrato** |  | 990d | 2019-02-13 | 2022-11-29 |  | 23d |  | 41,922,966 |  |
| 267 | 1.4.3.1.2.1.1 | Elaboración del diseño final |  | 220d | 2019-02-13 | 2019-12-17 | 155SS | 793d | 0d |  | Contratista |
| 268 | 1.4.3.1.2.1.2 | Diseño de las redes elaborado | milestone | 0d | 2019-12-17 | 2019-12-17 | 267 | 793d |  |  |  |
| 269 | 1.4.3.1.2.1.3 | Construcción de las colectoras |  | 930d | 2019-05-08 | 2022-11-29 | 157SS | 23d | 0d |  | Contratista |
| 270 | 1.4.3.1.2.1.4 | Redes construidas | milestone | 0d | 2022-11-29 | 2022-11-29 | 269 | 23d |  |  |  |
| 271 | 1.4.3.1.2.1.5 | **Pagos** |  | 530d | 2019-02-13 | 2021-02-23 |  | 483d |  | 41,922,966 |  |
| 272 | 1.4.3.1.2.1.5.1 | Pagos CL |  | 530d | 2019-02-13 | 2021-02-23 | 264SS | 483d |  | 41,922,966 | Adm. Financ. |
| 273 | 1.4.3.2 | **SBCC_8. Contratación de firma consultora para la supervisión de diseños y obras** |  | 1375d | 2017-09-25 | 2022-12-30 |  | 0d |  | 4,909,334 |  |
| 274 | 1.4.3.2.1 | **Ejecución de contrato** |  | 1375d | 2017-09-25 | 2022-12-30 |  | 0d |  | 4,909,334 |  |
| 275 | 1.4.3.2.1.1 | Pagos BID |  | 1375d | 2017-09-25 | 2022-12-30 | 175SS | 0d |  | 1,093,633 | Adm. Financ. |
| 276 | 1.4.3.2.1.2 | Pagos CL |  | 1375d | 2017-09-25 | 2022-12-30 | 275SS | 0d |  | 3,815,701 | Adm. Financ. |
| 277 | 1.5 | **Producto 5: Conexiones domiciliarias construidas** |  | 1411d | 2017-08-04 | 2022-12-30 |  | 0d |  | 49,266,323 |  |
| 278 | 1.5.1 | **Conexiones domiciliarias construidas en las cuencas de Prudente, Aguacate y Bernardino** |  | 910d | 2017-08-04 | 2021-01-28 |  | 501d |  | 12,832,731 |  |
| 279 | 1.5.1.1 | **LPI_1. Contratación de firma constructora para la instalación de conexiones domiciliarias** |  | 450d | 2019-04-09 | 2020-12-28 |  | 524d |  | 11,882,158 |  |
| 280 | 1.5.1.1.1 | **Cuenca de Prudente** |  | 450d | 2019-04-09 | 2020-12-28 |  | 524d |  | 4,183,973 |  |
| 281 | 1.5.1.1.1.1 | **Ejecución del contrato** |  | 450d | 2019-04-09 | 2020-12-28 |  | 524d |  | 4,183,973 |  |
| 282 | 1.5.1.1.1.1.1 | Construcción de las conexiones domiciliarias |  | 450d | 2019-04-09 | 2020-12-28 | 184SS | 524d | 0d |  | Contratista |
| 283 | 1.5.1.1.1.1.2 | Conexiones domiciliarias construidas | milestone | 0d | 2020-12-28 | 2020-12-28 | 282 | 524d |  |  |  |

| ID | WBS | Task | Type | Duration | Start | Finish | Predecessors | Total slack | Free slack | Cost | Text5 |
| --- | --- | --- | --- | --- | --- | --- | --- | --- | --- | --- | --- |
| 284 | 1.5.1.1.1.1.3 | **Pagos** |  | 450d | 2019-04-09 | 2020-12-28 |  | 524d |  | 4,183,973 |  |
| 285 | 1.5.1.1.1.1.3.1 | Pagos BCIE |  | 450d | 2019-04-09 | 2020-12-28 | 282SS | 524d | 0d | 3,910,256 | Adm. Financ. |
| 286 | 1.5.1.1.1.1.3.2 | Pagos CL |  | 450d | 2019-04-09 | 2020-12-28 | 285SS | 524d |  | 273,717 | Adm. Financ. |
| 287 | 1.5.1.1.2 | **Cuenca de Aguacate** |  | 450d | 2019-04-09 | 2020-12-28 |  | 524d |  | 2,152,997 |  |
| 288 | 1.5.1.1.2.1 | **Ejecución del contrato** |  | 450d | 2019-04-09 | 2020-12-28 |  | 524d |  | 2,152,997 |  |
| 289 | 1.5.1.1.2.1.1 | Construcción de las conexiones domiciliarias |  | 450d | 2019-04-09 | 2020-12-28 | 193SS | 524d | 0d |  | Contratista |
| 290 | 1.5.1.1.2.1.2 | Conexiones domiciliarias construidas | milestone | 0d | 2020-12-28 | 2020-12-28 | 289 | 524d |  |  |  |
| 291 | 1.5.1.1.2.1.3 | **Pagos** |  | 450d | 2019-04-09 | 2020-12-28 |  | 524d |  | 2,152,997 |  |
| 292 | 1.5.1.1.2.1.3.1 | Pagos BCIE |  | 450d | 2019-04-09 | 2020-12-28 | 289SS | 524d | 0d | 2,012,148 | Adm. Financ. |
| 293 | 1.5.1.1.2.1.3.2 | Pagos CL |  | 450d | 2019-04-09 | 2020-12-28 | 292SS | 524d |  | 140,849 | Adm. Financ. |
| 294 | 1.5.1.1.3 | **Cuenca de Bernardino** |  | 430d | 2019-04-30 | 2020-12-21 |  | 529d |  | 5,545,188 |  |
| 295 | 1.5.1.1.3.1 | **Ejecución del contrato** |  | 430d | 2019-04-30 | 2020-12-21 |  | 529d |  | 5,545,188 |  |
| 296 | 1.5.1.1.3.1.1 | Construcción de las conexiones domiciliarias |  | 430d | 2019-04-30 | 2020-12-21 | 201SS | 529d | 0d |  | Contratista |
| 297 | 1.5.1.1.3.1.2 | Conexiones domiciliarias construidas | milestone | 0d | 2020-12-21 | 2020-12-21 | 296 | 529d |  |  |  |
| 298 | 1.5.1.1.3.1.3 | **Pagos** |  | 430d | 2019-04-30 | 2020-12-21 |  | 529d |  | 5,545,188 |  |
| 299 | 1.5.1.1.3.1.3.1 | Pagos BEI |  | 430d | 2019-04-30 | 2020-12-21 | 296SS | 529d | 0d | 5,182,419 | Adm. Financ. |
| 300 | 1.5.1.1.3.1.3.2 | Pagos CL |  | 430d | 2019-04-30 | 2020-12-21 | 299SS | 529d |  | 362,769 | Adm. Financ. |
| 301 | 1.5.1.2 | **SBCC_6. Contratación de firma consultora para la supervisión de diseños y obras** |  | 910d | 2017-08-04 | 2021-01-28 |  | 501d |  | 950,573 |  |
| 302 | 1.5.1.2.1 | **Ejecución del contrato** |  | 910d | 2017-08-04 | 2021-01-28 |  | 501d |  | 950,573 |  |
| 303 | 1.5.1.2.1.1 | Pagos BID |  | 910d | 2017-08-04 | 2021-01-28 | 208SS | 501d | 0d | 760,780 | Adm. Financ. |
| 304 | 1.5.1.2.1.2 | Pagos CL |  | 910d | 2017-08-04 | 2021-01-28 | 303SS | 501d |  | 189,793 | Adm. Financ. |
| 305 | 1.5.2 | **Conexiones domiciliarias construidas en las cuencas Martín Sánchez I, Martín Sánchez II, Rodeo y Puerto Caimito** |  | 1135d | 2017-09-25 | 2022-01-28 |  | 240d |  | 21,550,904 |  |
| 306 | 1.5.2.1 | **LPI_2. Contratación de firma constructora para la instalación de conexiones domiciliarias** |  | 720d | 2019-03-27 | 2021-12-28 |  | 263d |  | 19,954,542 |  |
| 307 | 1.5.2.1.1 | **Cuenca de Martín Sánchez I** |  | 720d | 2019-03-27 | 2021-12-28 |  | 263d |  | 7,608,703 |  |
| 308 | 1.5.2.1.1.1 | **Ejecución del contrato** |  | 720d | 2019-03-27 | 2021-12-28 |  | 263d |  | 7,608,703 |  |
| 309 | 1.5.2.1.1.1.1 | Construcción de conexiones domiciliarias |  | 720d | 2019-03-27 | 2021-12-28 | 216SS | 263d | 0d |  | Contratista |
| 310 | 1.5.2.1.1.1.2 | Conexiones domiciliarias construidas | milestone | 0d | 2021-12-28 | 2021-12-28 | 309 | 263d |  |  |  |

| ID | WBS | Task | Type | Duration | Start | Finish | Predecessors | Total slack | Free slack | Cost | Text5 |
| --- | --- | --- | --- | --- | --- | --- | --- | --- | --- | --- | --- |
| 311 | 1.5.2.1.1.1.3 | **Pagos** |  | 720d | 2019-03-27 | 2021-12-28 |  | 263d |  | 7,608,703 |  |
| 312 | 1.5.2.1.1.1.3.1 | Pagos CL |  | 720d | 2019-03-27 | 2021-12-28 | 309SS | 263d |  | 7,608,703 | Adm. Financ. |
| 313 | 1.5.2.1.2 | **Cuenca de Martín Sánchez II** |  | 530d | 2019-12-18 | 2021-12-28 |  | 263d |  | 6,385,778 |  |
| 314 | 1.5.2.1.2.1 | **Ejecución del contrato** |  | 530d | 2019-12-18 | 2021-12-28 |  | 263d |  | 6,385,778 |  |
| 315 | 1.5.2.1.2.1.1 | Construcción de conexiones domiciliarias |  | 530d | 2019-12-18 | 2021-12-28 | 227SS | 263d | 0d |  | Contratista |
| 316 | 1.5.2.1.2.1.2 | Conexiones domiciliarias construidas | milestone | 0d | 2021-12-28 | 2021-12-28 | 315 | 263d |  |  |  |
| 317 | 1.5.2.1.2.1.3 | **Pagos** |  | 530d | 2019-12-18 | 2021-12-28 |  | 263d |  | 6,385,778 |  |
| 318 | 1.5.2.1.2.1.3.1 | Pagos BCIE |  | 530d | 2019-12-18 | 2021-12-28 | 315SS | 263d | 0d | 5,968,017 | Adm. Financ. |
| 319 | 1.5.2.1.2.1.3.2 | Pagos CL |  | 530d | 2019-12-18 | 2021-12-28 | 318SS | 263d |  | 417,761 | Adm. Financ. |
| 320 | 1.5.2.1.3 | **Cuenca de Rodeo** |  | 555d | 2019-03-27 | 2021-05-11 |  | 428d |  | 4,091,780 |  |
| 321 | 1.5.2.1.3.1 | **Ejecución del contrato** |  | 555d | 2019-03-27 | 2021-05-11 |  | 428d |  | 4,091,780 |  |
| 322 | 1.5.2.1.3.1.1 | Construcción de conexiones domiciliarias |  | 555d | 2019-03-27 | 2021-05-11 | 245SS | 428d | 0d |  | Contratista |
| 323 | 1.5.2.1.3.1.2 | Conexiones domiciliarias construidas | milestone | 0d | 2021-05-11 | 2021-05-11 | 322 | 428d |  |  |  |
| 324 | 1.5.2.1.3.1.3 | **Pagos** |  | 555d | 2019-03-27 | 2021-05-11 |  | 428d |  | 4,091,780 |  |
| 325 | 1.5.2.1.3.1.3.1 | Pagos BCIE |  | 555d | 2019-03-27 | 2021-05-11 | 322SS | 428d | 0d | 3,824,094 | Adm. Financ. |
| 326 | 1.5.2.1.3.1.3.2 | Pagos CL |  | 555d | 2019-03-27 | 2021-05-11 | 325SS | 428d |  | 267,686 | Adm. Financ. |
| 327 | 1.5.2.1.4 | **Cuenca de Puerto Caimito** |  | 330d | 2019-06-12 | 2020-09-15 |  | 598d |  | 1,868,281 |  |
| 328 | 1.5.2.1.4.1 | **Ejecución del contrato** |  | 330d | 2019-06-12 | 2020-09-15 |  | 598d |  | 1,868,281 |  |
| 329 | 1.5.2.1.4.1.1 | Construcción de conexiones domiciliarias |  | 330d | 2019-06-12 | 2020-09-15 | 237SS | 598d | 0d |  | Contratista |
| 330 | 1.5.2.1.4.1.2 | Conexiones domiciliarias construidas | milestone | 0d | 2020-09-15 | 2020-09-15 | 329 | 598d |  |  |  |
| 331 | 1.5.2.1.4.1.3 | **Pagos** |  | 330d | 2019-06-12 | 2020-09-15 |  | 598d |  | 1,868,281 |  |
| 332 | 1.5.2.1.4.1.3.1 | Pagos CL |  | 330d | 2019-06-12 | 2020-09-15 | 329SS | 598d |  | 1,868,281 | Adm. Financ. |
| 333 | 1.5.2.2 | **SBCC_7. Contratación de firma consultora para la supervisión de diseños y obras** |  | 1135d | 2017-09-25 | 2022-01-28 |  | 240d |  | 1,596,362 |  |
| 334 | 1.5.2.2.1 | **Ejecución de contrato** |  | 1135d | 2017-09-25 | 2022-01-28 |  | 240d |  | 1,596,362 |  |
| 335 | 1.5.2.2.1.1 | Pagos BID |  | 1135d | 2017-09-25 | 2022-01-28 | 253SS | 240d | 0d | 355,614 | Adm. Financ. |
| 336 | 1.5.2.2.1.2 | Pagos CL |  | 1135d | 2017-09-25 | 2022-01-28 | 335SS | 240d |  | 1,240,748 | Adm. Financ. |

Notes:
- 322: dic 2019 a mar 2022

| ID | WBS | Task | Type | Duration | Start | Finish | Predecessors | Total slack | Free slack | Cost | Text5 |
| --- | --- | --- | --- | --- | --- | --- | --- | --- | --- | --- | --- |
| 337 | 1.5.3 | **Conexiones domiciliarias construidas en las cuencas de Caimito I y Caimito II** |  | 1375d | 2017-09-25 | 2022-12-30 |  | 0d |  | 14,882,688 |  |
| 338 | 1.5.3.1 | **LPI_3. Contratación de firma para el diseño y construcción de obras** |  | 930d | 2019-05-08 | 2022-11-29 |  | 23d |  | 13,780,267 |  |
| 339 | 1.5.3.1.1 | **Cuenca de Caimito I** |  | 895d | 2019-05-08 | 2022-10-11 |  | 58d |  | 3,652,503 |  |
| 340 | 1.5.3.1.1.1 | **Ejecución del contrato** |  | 895d | 2019-05-08 | 2022-10-11 |  | 58d |  | 3,652,503 |  |
| 341 | 1.5.3.1.1.1.1 | Construcción de conexiones domiciliarias |  | 895d | 2019-05-08 | 2022-10-11 | 261SS | 58d | 0d |  | Contratista |
| 342 | 1.5.3.1.1.1.2 | Conexiones domiciliarias construidas | milestone | 0d | 2022-10-11 | 2022-10-11 | 341 | 58d |  |  |  |
| 343 | 1.5.3.1.1.1.3 | **Pagos** |  | 895d | 2019-05-08 | 2022-10-11 |  | 58d |  | 3,652,503 |  |
| 344 | 1.5.3.1.1.1.3.1 | Pagos CL |  | 895d | 2019-05-08 | 2022-10-11 | 341SS | 58d |  | 3,652,503 | Adm. Financ. |
| 345 | 1.5.3.1.2 | **Cuenca de Caimito II** |  | 930d | 2019-05-08 | 2022-11-29 |  | 23d |  | 10,127,764 |  |
| 346 | 1.5.3.1.2.1 | **Ejecución del contrato** |  | 930d | 2019-05-08 | 2022-11-29 |  | 23d |  | 10,127,764 |  |
| 347 | 1.5.3.1.2.1.1 | Construcción de conexiones domiciliarias |  | 930d | 2019-05-08 | 2022-11-29 | 269SS | 23d | 0d |  | Contratista |
| 348 | 1.5.3.1.2.1.2 | Conexiones domiciliarias construidas | milestone | 0d | 2022-11-29 | 2022-11-29 | 347 | 23d |  |  |  |
| 349 | 1.5.3.1.2.1.3 | **Pagos** |  | 930d | 2019-05-08 | 2022-11-29 |  | 23d |  | 10,127,764 |  |
| 350 | 1.5.3.1.2.1.3.1 | Pagos CL |  | 930d | 2019-05-08 | 2022-11-29 | 347SS | 23d |  | 10,127,764 | Adm. Financ. |
| 351 | 1.5.3.2 | **SBCC_8. Contratación de firma consultora para la supervisión de diseños y obras** |  | 1375d | 2017-09-25 | 2022-12-30 |  | 0d |  | 1,102,421 |  |
| 352 | 1.5.3.2.1 | **Ejecución de contrato** |  | 1375d | 2017-09-25 | 2022-12-30 |  | 0d |  | 1,102,421 |  |
| 353 | 1.5.3.2.1.1 | Pagos BID |  | 1375d | 2017-09-25 | 2022-12-30 | 275SS | 0d |  | 245,582 | Adm. Financ. |
| 354 | 1.5.3.2.1.2 | Pagos CL |  | 1375d | 2017-09-25 | 2022-12-30 | 353SS | 0d |  | 856,839 | Adm. Financ. |
| 355 | 1.6 | **Producto 6: Primer módulo de la PTAR e interceptor (Caimito) operando** |  | 260d | 2021-10-22 | 2022-10-21 |  | 50d |  | 15,000,000 |  |
| 356 | 1.6.1 | **LPI_1. Contratación de firma para la Operación y Mantenimiento de la PTAR Caimito** |  | 260d | 2021-10-22 | 2022-10-21 |  | 50d |  | 15,000,000 |  |
| 357 | 1.6.1.1 | **Ejecución del contrato** |  | 260d | 2021-10-22 | 2022-10-21 |  | 50d |  | 15,000,000 |  |
| 358 | 1.6.1.1.1 | Traspaso de obra para O&M | milestone | 0d | 2021-10-22 | 2021-10-22 | 26FS+4d | 50d | 0d |  |  |
| 359 | 1.6.1.1.2 | Ejecución de la O&M |  | 260d | 2021-10-25 | 2022-10-21 | 358 | 50d | 0d |  | Contratista |
| 360 | 1.6.1.1.3 | O&M realizada | milestone | 0d | 2022-10-21 | 2022-10-21 | 359 | 50d |  |  |  |

| ID | WBS | Task | Type | Duration | Start | Finish | Predecessors | Total slack | Free slack | Cost | Text5 |
| --- | --- | --- | --- | --- | --- | --- | --- | --- | --- | --- | --- |
| 361 | 1.6.1.1.4 | **Pagos** |  | 260d | 2021-10-25 | 2022-10-21 |  | 50d |  | 15,000,000 |  |
| 362 | 1.6.1.1.4.1 | Pagos CL |  | 260d | 2021-10-25 | 2022-10-21 | 359SS | 50d |  | 15,000,000 | Adm. Financ. |
| 363 | 2 | **Componente 2: Fortalecimiento Institucional** |  | 1540d | 2017-02-06 | 2022-12-30 |  | 0d |  | 10,240,017 |  |
| 364 | 2.1 | **Producto 7: Actividades de capacitación en O&M e implementación del SIG desarrolladas** |  | 1470d | 2017-05-09 | 2022-12-26 |  | 4d |  | 1,425,000 |  |
| 365 | 2.1.1 | **CCIN_20. Consultoría individual para la elaboración del Plan de Capacitación para la UCP** |  | 150d | 2017-05-09 | 2017-12-04 |  | 4d |  | 50,000 |  |
| 366 | 2.1.1.1 | Etapa previa |  | 20d | 2017-05-09 | 2017-06-05 | 13FS+22d | 4d | 0d |  | Resp. FI |
| 367 | 2.1.1.2 | Etapa de contratación |  | 45d | 2017-06-06 | 2017-08-07 | 366 | 4d | 0d |  | Gte. Leg. Y Contr. |
| 368 | 2.1.1.3 | Formalización del contrato |  | 20d | 2017-08-08 | 2017-09-04 | 367 | 4d | 0d |  | Gte. Leg. Y Contr. |
| 369 | 2.1.1.4 | Ejecución del contrato |  | 65d | 2017-09-05 | 2017-12-04 | 368 | 4d | 0d |  | Firma |
| 370 | 2.1.1.5 | Plan de capacitación elaborado | milestone | 0d | 2017-12-04 | 2017-12-04 | 369 | 1324d |  |  |  |
| 371 | 2.1.1.6 | **Pagos** |  | 65d | 2017-09-05 | 2017-12-04 |  | 1324d |  | 50,000 |  |
| 372 | 2.1.1.6.1 | Pagos BID |  | 65d | 2017-09-05 | 2017-12-04 | 369SS | 1324d | 0d | 34,000 | Adm. Financ. |
| 373 | 2.1.1.6.2 | Pagos CAF |  | 65d | 2017-09-05 | 2017-12-04 | 372SS | 1324d | 0d | 12,000 | Adm. Financ. |
| 374 | 2.1.1.6.3 | Pagos CL |  | 65d | 2017-09-05 | 2017-12-04 | 373SS | 1324d |  | 4,000 | Adm. Financ. |
| 375 | 2.1.2 | **CP_24. Implementación del plan de capacitación para la UCP en temas de habilidades blandas y metodologías de gestión de proyectos** |  | 615d | 2017-12-05 | 2020-04-13 |  | 709d |  | 895,000 |  |
| 376 | 2.1.2.1 | Etapa previa |  | 20d | 2017-12-05 | 2018-01-01 | 369 | 709d | 0d |  | Resp. FI |
| 377 | 2.1.2.2 | Etapa de contratación |  | 45d | 2018-01-02 | 2018-03-05 | 376 | 709d | 0d |  | Gte. Leg. Y Contr. |
| 378 | 2.1.2.3 | Formalización del contrato |  | 20d | 2018-03-06 | 2018-04-02 | 377 | 709d | 0d |  | Gte. Leg. Y Contr. |
| 379 | 2.1.2.4 | Ejecución del contrato |  | 530d | 2018-04-03 | 2020-04-13 | 378 | 709d | 0d |  | Firma |
| 380 | 2.1.2.5 | **Pagos** |  | 530d | 2018-04-03 | 2020-04-13 |  | 709d |  | 895,000 |  |
| 381 | 2.1.2.5.1 | Pagos BID |  | 530d | 2018-04-03 | 2020-04-13 | 379SS | 709d | 0d | 608,600 | Adm. Financ. |
| 382 | 2.1.2.5.2 | Pagos CAF |  | 530d | 2018-04-03 | 2020-04-13 | 381SS | 709d | 0d | 214,800 | Adm. Financ. |
| 383 | 2.1.2.5.3 | Pagos CL |  | 530d | 2018-04-03 | 2020-04-13 | 382SS | 709d |  | 71,600 | Adm. Financ. |
| 384 | 2.1.3 | Desarrollo de otras actividades a definir |  | 1320d | 2017-12-05 | 2022-12-26 | 369 | 4d | 0d | 480,000 | Resp. FI |
| 385 | 2.1.4 | Actividades de capacitación implementadas | milestone | 0d | 2022-12-26 | 2022-12-26 | 379, 384 | 4d |  |  |  |

| ID | WBS | Task | Type | Duration | Start | Finish | Predecessors | Total slack | Free slack | Cost | Text5 |
| --- | --- | --- | --- | --- | --- | --- | --- | --- | --- | --- | --- |
| 386 | 2.2 | **Producto 8: Instrumento reglamentario del Convenio IDAAN – UCP aprobado** |  | 300d | 2017-02-06 | 2018-03-30 |  | 1240d |  | 475,000 |  |
| 387 | 2.2.1 | **SCC_9. Consultoría para la elaboración del instrumento reglamentario para la implementación del Convenio IDAAN/MINSA** |  | 300d | 2017-02-06 | 2018-03-30 |  | 1240d |  | 100,000 |  |
| 388 | 2.2.1.1 | Etapa previa |  | 20d | 2017-02-06 | 2017-03-03 | 13FS-44d | 1240d | 0d |  | Resp. FI |
| 389 | 2.2.1.2 | Expresión de interés |  | 30d | 2017-03-06 | 2017-04-14 | 388 | 1240d | 0d |  | Gte. Leg. Y Contr. |
| 390 | 2.2.1.3 | Etapa de contratación |  | 100d | 2017-04-17 | 2017-09-01 | 389 | 1240d | 0d |  | Gte. Leg. Y Contr. |
| 391 | 2.2.1.4 | Formalización del contrato |  | 20d | 2017-09-04 | 2017-09-29 | 390 | 1240d | 0d |  | Gte. Leg. Y Contr. |
| 392 | 2.2.1.5 | Ejecución del contrato |  | 130d | 2017-10-02 | 2018-03-30 | 391 | 1240d | 0d |  | Firma |
| 393 | 2.2.1.6 | Instrumento reglamentario elaborado | milestone | 0d | 2018-03-30 | 2018-03-30 | 392 | 1240d |  |  |  |
| 394 | 2.2.1.7 | **Pagos** |  | 130d | 2017-10-02 | 2018-03-30 |  | 1240d |  | 100,000 |  |
| 395 | 2.2.1.7.1 | Pagos BID |  | 130d | 2017-10-02 | 2018-03-30 | 392SS | 1240d | 0d | 93,458 | Adm. Financ. |
| 396 | 2.2.1.7.2 | Pagos CL |  | 130d | 2017-10-02 | 2018-03-30 | 395SS | 1240d | 0d | 6,542 | Adm. Financ. |
| 397 | 2.2.2 | Recursos adicionales |  | 130d | 2017-10-02 | 2018-03-30 | 396SS | 1240d |  | 375,000 | Resp. FI |
| 398 | 2.3 | **Producto 9: Catastro técnico para verificación de los sistemas pluvial y sanitario existentes, realizada** |  | 730d | 2017-06-14 | 2020-03-31 |  | 718d |  | 2,075,000 |  |
| 399 | 2.3.1 | **SBCC_14. Consultoría para realizar el catastro técnico para verificación de los sistemas de saneamiento** |  | 730d | 2017-06-14 | 2020-03-31 |  | 718d |  | 2,075,000 |  |
| 400 | 2.3.1.1 | Etapa previa |  | 20d | 2017-06-14 | 2017-07-11 | 13FS+48d | 718d | 0d |  | Resp. FI |
| 401 | 2.3.1.2 | Expresión de interés |  | 30d | 2017-07-12 | 2017-08-22 | 400 | 718d | 0d |  | Gte. Leg. Y Contr. |
| 402 | 2.3.1.3 | Etapa de contratación |  | 130d | 2017-08-23 | 2018-02-20 | 401 | 718d | 0d |  | Gte. Leg. Y Contr. |
| 403 | 2.3.1.4 | Formalización del contrato |  | 20d | 2018-02-21 | 2018-03-20 | 402 | 718d | 0d |  | Gte. Leg. Y Contr. |
| 404 | 2.3.1.5 | Ejecución del contrato |  | 530d | 2018-03-21 | 2020-03-31 | 403 | 718d | 0d |  | Firma |
| 405 | 2.3.1.6 | Catastro técnico realizado - Año 2 | milestone | 0d | 2019-03-25 | 2019-03-25 | 404SS+264d | 984d |  |  |  |
| 406 | 2.3.1.7 | Catastro técnico realizado- Año 3 | milestone | 0d | 2020-03-31 | 2020-03-31 | 404 | 718d |  |  |  |
| 407 | 2.3.1.8 | **Pagos** |  | 530d | 2018-03-21 | 2020-03-31 |  | 718d |  | 2,075,000 |  |
| 408 | 2.3.1.8.1 | Pagos BID |  | 530d | 2018-03-21 | 2020-03-31 | 404SS | 718d | 0d | 1,462,241 | Adm. Financ. |
| 409 | 2.3.1.8.2 | Pagos CAF |  | 530d | 2018-03-21 | 2020-03-31 | 408SS | 718d | 0d | 477,011 | Adm. Financ. |
| 410 | 2.3.1.8.3 | Pagos CL |  | 530d | 2018-03-21 | 2020-03-31 | 409SS | 718d |  | 135,748 | Adm. Financ. |

| ID | WBS | Task | Type | Duration | Start | Finish | Predecessors | Total slack | Free slack | Cost | Text5 |
| --- | --- | --- | --- | --- | --- | --- | --- | --- | --- | --- | --- |
| 411 | 2.4 | **Producto 10: Programa de monitoreo de la calidad de agua de ríos y quebradas del PSACH** |  | 935d | 2019-06-03 | 2022-12-30 |  | 0d |  | 1,900,000 |  |
| 412 | 2.4.1 | **SBC_13. Consultoría para la realización de actividades del Programa de monitoreo de la calidad del agua** |  | 935d | 2019-06-03 | 2022-12-30 |  | 0d |  | 1,500,000 |  |
| 413 | 2.4.1.1 | Etapa previa |  | 20d | 2019-06-03 | 2019-06-28 | 13FS+561d | 0d |  |  | Resp. FI |
| 414 | 2.4.1.2 | Expresión de interés |  | 30d | 2019-07-01 | 2019-08-09 | 413 | 0d |  |  | Gte. Leg. Y Contr. |
| 415 | 2.4.1.3 | Etapa de contratación |  | 130d | 2019-08-12 | 2020-02-07 | 414 | 0d |  |  | Gte. Leg. Y Contr. |
| 416 | 2.4.1.4 | Formalización del contrato |  | 20d | 2020-02-10 | 2020-03-06 | 415 | 0d |  |  | Gte. Leg. Y Contr. |
| 417 | 2.4.1.5 | Ejecución del contrato |  | 735d | 2020-03-09 | 2022-12-30 | 416 | 0d |  |  | Firma |
| 418 | 2.4.1.6 | Hito 1: Línea de base actualizada | milestone | 0d | 2020-03-09 | 2020-03-09 | 417SS | 475d | 0d |  |  |
| 419 | 2.4.1.7 | Hito 2: Campaña de monitoreo realizada - Año 5 | milestone | 0d | 2021-03-05 | 2021-03-05 | 418FS+260d | 475d |  |  |  |
| 420 | 2.4.1.8 | Hito 2: Campaña de monitoreo realizada - Año 6 | milestone | 0d | 2022-12-30 | 2022-12-30 | 417 | 0d |  |  |  |
| 421 | 2.4.1.9 | **Pagos** |  | 735d | 2020-03-09 | 2022-12-30 |  | 0d |  | 1,500,000 |  |
| 422 | 2.4.1.9.1 | Pagos BID |  | 735d | 2020-03-09 | 2022-12-30 | 417SS | 0d |  | 1,050,000 | Adm. Financ. |
| 423 | 2.4.1.9.2 | Pagos CAF |  | 735d | 2020-03-09 | 2022-12-30 | 422SS | 0d |  | 345,000 | Adm. Financ. |
| 424 | 2.4.1.9.3 | Pagos CL |  | 735d | 2020-03-09 | 2022-12-30 | 423SS | 0d |  | 105,000 | Adm. Financ. |
| 425 | 2.4.2 | Recusos adicionales |  | 735d | 2020-03-09 | 2022-12-30 | 424SS | 0d |  | 400,000 | Resp. FI |
| 426 | 2.5 | **Producto 11: Programa de monitoreo y control de descargas industriales al alcantarillado sanitario, implementado** |  | 730d | 2020-02-13 | 2022-11-30 |  | 22d |  | 2,490,000 |  |
| 427 | 2.5.1 | **SBCC_15. Consultoría para la elaboración del programa de monitoreo y control de descargas industriales** |  | 730d | 2020-02-13 | 2022-11-30 |  | 22d |  | 2,490,000 |  |
| 428 | 2.5.1.1 | Etapa previa |  | 20d | 2020-02-13 | 2020-03-11 | 13FS+744d | 22d | 0d |  | Resp. FI |
| 429 | 2.5.1.2 | Expresión de interés |  | 30d | 2020-03-12 | 2020-04-22 | 428 | 22d | 0d |  | Gte. Leg. Y Contr. |
| 430 | 2.5.1.3 | Etapa de contratación |  | 130d | 2020-04-23 | 2020-10-21 | 429 | 22d | 0d |  | Gte. Leg. Y Contr. |
| 431 | 2.5.1.4 | Formalización del contrato |  | 20d | 2020-10-22 | 2020-11-18 | 430 | 22d | 0d |  | Gte. Leg. Y Contr. |
| 432 | 2.5.1.5 | Ejecución del contrato |  | 530d | 2020-11-19 | 2022-11-30 | 431 | 22d | 0d |  | Firma |
| 433 | 2.5.1.6 | Hito 1: Actualización de grandes contaminantes de descargas de aguas residuales no domésticos realizada | milestone | 0d | 2020-02-13 | 2020-02-13 | 428SS | 224d | 0d |  |  |
| 434 | 2.5.1.7 | Hito 2: Programa de monitoreo diseñado | milestone | 0d | 2021-02-16 | 2021-02-16 | 433FS+264d | 224d | 0d |  |  |
| 435 | 2.5.1.8 | Hito 3: Campaña de monitoreo realizada - Año 5 | milestone | 0d | 2022-02-21 | 2022-02-21 | 434SS+264d | 224d |  |  |  |
| 436 | 2.5.1.9 | Hito 3: Campaña de monitoreo realizada - Año 6 | milestone | 0d | 2022-11-30 | 2022-11-30 | 432 | 22d |  |  |  |

| ID | WBS | Task | Type | Duration | Start | Finish | Predecessors | Total slack | Free slack | Cost | Text5 |
| --- | --- | --- | --- | --- | --- | --- | --- | --- | --- | --- | --- |
| 437 | 2.5.1.10 | **Pagos** |  | 530d | 2020-11-19 | 2022-11-30 |  | 22d |  | 2,490,000 |  |
| 438 | 2.5.1.10.1 | Pagos BID |  | 530d | 2020-11-19 | 2022-11-30 | 432SS | 22d | 0d | 1,754,689 | Adm. Financ. |
| 439 | 2.5.1.10.2 | Pagos CAF |  | 530d | 2020-11-19 | 2022-11-30 | 438SS | 22d | 0d | 572,414 | Adm. Financ. |
| 440 | 2.5.1.10.3 | Pagos CL |  | 530d | 2020-11-19 | 2022-11-30 | 439SS | 22d |  | 162,897 | Adm. Financ. |
| 441 | 2.6 | **Producto 12: Plan de Fortalecimiento de DISAPAS implementado** |  | 730d | 2020-02-13 | 2022-11-30 |  | 22d |  | 914,000 |  |
| 442 | 2.6.1 | **SBCC_10. Consultoría para la elaboración de un diagnóstico y de un plan de fortalecimiento para la DISAPAS, incluyendo la implementación** |  | 730d | 2020-02-13 | 2022-11-30 |  | 22d |  | 500,000 |  |
| 443 | 2.6.1.1 | Etapa previa |  | 20d | 2020-02-13 | 2020-03-11 | 428SS | 22d | 0d |  | Resp. FI |
| 444 | 2.6.1.2 | Expresión de interés |  | 30d | 2020-03-12 | 2020-04-22 | 443 | 22d | 0d |  | Gte. Leg. Y Contr. |
| 445 | 2.6.1.3 | Etapa de contratación |  | 130d | 2020-04-23 | 2020-10-21 | 444 | 22d | 0d |  | Gte. Leg. Y Contr. |
| 446 | 2.6.1.4 | Formalización del contrato |  | 20d | 2020-10-22 | 2020-11-18 | 445 | 22d | 0d |  | Gte. Leg. Y Contr. |
| 447 | 2.6.1.5 | Ejecución del contrato |  | 530d | 2020-11-19 | 2022-11-30 | 446 | 22d | 0d |  | Firma |
| 448 | 2.6.1.6 | Hito 1: Diagnóstico y plan diseñados | milestone | 0d | 2020-02-13 | 2020-02-13 | 443SS | 264d | 0d |  |  |
| 449 | 2.6.1.7 | Hito 2: Actividades del Plan desarrolladas - Año 4 | milestone | 0d | 2020-12-22 | 2020-12-22 | 448FS+224d | 264d | 0d |  |  |
| 450 | 2.6.1.8 | Hito 2: Actividades del Plan desarrolladas - Año 5 | milestone | 0d | 2021-12-27 | 2021-12-27 | 449FS+264d | 264d |  |  |  |
| 451 | 2.6.1.9 | Hito 2: Actividades del Plan desarrolladas - Año 6 | milestone | 0d | 2022-11-30 | 2022-11-30 | 447 | 22d |  |  |  |
| 452 | 2.6.1.10 | **Pagos** |  | 530d | 2020-11-19 | 2022-11-30 |  | 22d |  | 500,000 |  |
| 453 | 2.6.1.10.1 | Pagos BID |  | 530d | 2020-11-19 | 2022-11-30 | 447SS | 22d | 0d | 467,290 | Adm. Financ. |
| 454 | 2.6.1.10.2 | Pagos CL |  | 530d | 2020-11-19 | 2022-11-30 | 453SS | 22d | 0d | 32,710 | Adm. Financ. |
| 455 | 2.6.2 | Recursos adicionales |  | 530d | 2020-11-19 | 2022-11-30 | 454SS | 22d |  | 414,000 | Resp. FI |
| 456 | 2.7 | **Producto 13: Actividades para fortalecer la sostenibilidad del sistema de saneamiento, implementadas** |  | 1081d | 2017-12-21 | 2022-02-10 |  | 231d |  | 961,017 |  |
| 457 | 2.7.1 | **SBCC_11. Consultoría para la elaboración e implementación de un plan de fortalecimiento para el sector saneamiento** |  | 730d | 2018-03-23 | 2021-01-07 |  | 231d |  | 500,000 |  |
| 458 | 2.7.1.1 | Etapa previa |  | 20d | 2018-03-23 | 2018-04-19 | 13FS+250d | 231d | 0d |  | Resp. FI |
| 459 | 2.7.1.2 | Expresión de interés |  | 30d | 2018-04-20 | 2018-05-31 | 458 | 231d | 0d |  | Gte. Leg. Y Contr. |
| 460 | 2.7.1.3 | Etapa de contratación |  | 130d | 2018-06-01 | 2018-11-29 | 459 | 231d | 0d |  | Gte. Leg. Y Contr. |
| 461 | 2.7.1.4 | Formalización del contrato |  | 20d | 2018-11-30 | 2018-12-27 | 460 | 231d | 0d |  | Gte. Leg. Y Contr. |
| 462 | 2.7.1.5 | Ejecución del contrato |  | 530d | 2018-12-28 | 2021-01-07 | 461 | 231d | 0d |  | Firma |
| 463 | 2.7.1.6 | Hito 1: Instrumento para reglamentar el funcionamiento del Comité elaborado | milestone | 0d | 2019-03-29 | 2019-03-29 | 462SS+66d | 231d | 0d |  |  |
| 464 | 2.7.1.7 | Hito 2: Actividades de transferencia de conocimientos- Año 3 | milestone | 0d | 2020-03-27 | 2020-03-27 | 463FS+260d | 720d |  |  |  |
| 465 | 2.7.1.8 | Hito 2: Actividades de transferencia de conocimientos - Año 4 | milestone | 0d | 2021-01-07 | 2021-01-07 | 462 | 516d |  |  |  |

| ID | WBS | Task | Type | Duration | Start | Finish | Predecessors | Total slack | Free slack | Cost | Text5 |
| --- | --- | --- | --- | --- | --- | --- | --- | --- | --- | --- | --- |
| 466 | 2.7.1.9 | **Pagos** |  | 530d | 2018-12-28 | 2021-01-07 |  | 516d |  | 500,000 |  |
| 467 | 2.7.1.9.1 | Pagos BID |  | 530d | 2018-12-28 | 2021-01-07 | 462SS | 516d | 0d | 230,000 | Adm. Financ. |
| 468 | 2.7.1.9.2 | Pagos CAF |  | 530d | 2018-12-28 | 2021-01-07 | 467SS | 516d | 0d | 240,000 | Adm. Financ. |
| 469 | 2.7.1.9.3 | Pagos CL |  | 530d | 2018-12-28 | 2021-01-07 | 468SS | 516d |  | 30,000 | Adm. Financ. |
| 470 | 2.7.2 | **CP_5. Realización de actividades complementarias del plan de fortalecimiento** |  | 485d | 2020-04-03 | 2022-02-10 |  | 231d |  | 50,000 |  |
| 471 | 2.7.2.1 | Etapa previa |  | 20d | 2020-04-03 | 2020-04-30 | 463FS+264d | 231d | 0d |  | Resp. FI |
| 472 | 2.7.2.2 | Etapa de contratación |  | 45d | 2020-05-01 | 2020-07-02 | 471 | 231d | 0d |  | Gte. Leg. Y Contr. |
| 473 | 2.7.2.3 | Formalización del contrato |  | 20d | 2020-07-03 | 2020-07-30 | 472 | 231d | 0d |  | Gte. Leg. Y Contr. |
| 474 | 2.7.2.4 | Ejecución del contrato |  | 400d | 2020-07-31 | 2022-02-10 | 473 | 231d | 0d |  | Firma |
| 475 | 2.7.2.5 | Hito 2: Actividades de transferencia de conocimientos - Año 5 | milestone | 0d | 2022-02-10 | 2022-02-10 | 474 | 231d |  |  |  |
| 476 | 2.7.2.6 | **Pagos** |  | 400d | 2020-07-31 | 2022-02-10 |  | 231d |  | 50,000 |  |
| 477 | 2.7.2.6.1 | Pagos BID |  | 400d | 2020-07-31 | 2022-02-10 | 474SS | 231d | 0d | 23,000 | Adm. Financ. |
| 478 | 2.7.2.6.2 | Pagos CAF |  | 400d | 2020-07-31 | 2022-02-10 | 477SS | 231d | 0d | 24,000 | Adm. Financ. |
| 479 | 2.7.2.6.3 | Pagos CL |  | 400d | 2020-07-31 | 2022-02-10 | 478SS | 231d |  | 3,000 | Adm. Financ. |
| 480 | 2.7.3 | **SCC_12. Elaboración de la propuesta de adecuación de la estructura y del nivel tarifario de los servicios de alcantarillado sanitario** |  | 260d | 2017-12-21 | 2018-12-19 |  | 1052d |  | 200,000 |  |
| 481 | 2.7.3.1 | Etapa previa |  | 20d | 2017-12-21 | 2018-01-17 | 458SS-66d | 1052d | 0d |  | Resp. FI |
| 482 | 2.7.3.2 | Expresión de interés |  | 30d | 2018-01-18 | 2018-02-28 | 481 | 1052d | 0d |  | Gte. Leg. Y Contr. |
| 483 | 2.7.3.3 | Etapa de contratación |  | 100d | 2018-03-01 | 2018-07-18 | 482 | 1052d | 0d |  | Gte. Leg. Y Contr. |
| 484 | 2.7.3.4 | Formalización del contrato |  | 20d | 2018-07-19 | 2018-08-15 | 483 | 1052d | 0d |  | Gte. Leg. Y Contr. |
| 485 | 2.7.3.5 | Ejecución del contrato |  | 90d | 2018-08-16 | 2018-12-19 | 484 | 1052d | 0d |  | Firma |
| 486 | 2.7.3.6 | Propuesta de estructura tarifaria aprobada | milestone | 0d | 2018-12-19 | 2018-12-19 | 485 | 1052d |  |  |  |
| 487 | 2.7.3.7 | **Pagos** |  | 90d | 2018-08-16 | 2018-12-19 |  | 1052d |  | 200,000 |  |
| 488 | 2.7.3.7.1 | Pagos BID |  | 90d | 2018-08-16 | 2018-12-19 | 485SS | 1052d | 0d | 186,916 | Adm. Financ. |
| 489 | 2.7.3.7.2 | Pagos CL |  | 90d | 2018-08-16 | 2018-12-19 | 488SS | 1052d |  | 13,084 | Adm. Financ. |
| 490 | 2.7.4 | Recursos adicionales |  | 785d | 2018-12-28 | 2021-12-30 | 462SS | 261d |  | 211,017 | Resp. FI |

| ID | WBS | Task | Type | Duration | Start | Finish | Predecessors | Total slack | Free slack | Cost | Text5 |
| --- | --- | --- | --- | --- | --- | --- | --- | --- | --- | --- | --- |
| 491 | 3 | **Componente 3: Estudios y Acciones Complementarias** |  | 1824d | 2016-01-04 | 2022-12-29 |  | 1d |  | 3,735,000 |  |
| 492 | 3.1 | **Producto 14: Proyecto piloto de protección de servidumbre de alcantarillado que genere espacios recreativos en márgenes de ríos, implementado** |  | 1824d | 2016-01-04 | 2022-12-29 |  | 1d |  | 3,320,000 |  |
| 493 | 3.1.1 | **LPI_4. Contratación de firma para la elaboración del proyecto piloto y ejecución de las obras** |  | 690d | 2020-04-09 | 2022-11-30 |  | 1d |  | 3,062,399 |  |
| 494 | 3.1.1.1 | Etapa previa |  | 65d | 2020-04-09 | 2020-07-08 | 173FS+663d | 1d | 0d |  | Resp. FI |
| 495 | 3.1.1.2 | Etapa de contratación |  | 135d | 2020-07-09 | 2021-01-13 | 494 | 22d | 0d |  | Gte. Leg. Y Contr. |
| 496 | 3.1.1.3 | Formalización del contrato |  | 90d | 2021-01-14 | 2021-05-19 | 495 | 22d | 0d |  | Gte. Leg. Y Contr. |
| 497 | 3.1.1.4 | **Ejecución del contrato** |  | 400d | 2021-05-20 | 2022-11-30 | 496 | 22d |  | 3,062,399 |  |
| 498 | 3.1.1.4.1 | Elaboración del diseño final del proyecto |  | 70d | 2021-05-20 | 2021-08-25 |  | 22d | 0d |  | Contratista |
| 499 | 3.1.1.4.2 | Diseño del proyecto piloto elaborado | milestone | 0d | 2021-08-25 | 2021-08-25 | 498 | 22d | 0d |  |  |
| 500 | 3.1.1.4.3 | Construcción de obras para protección de servidumbres |  | 330d | 2021-08-26 | 2022-11-30 | 499 | 22d | 0d |  | Contratista |
| 501 | 3.1.1.4.4 | Proyecto piloto de protección de servidumbre construido | milestone | 0d | 2022-11-30 | 2022-11-30 | 500 | 22d |  |  |  |
| 502 | 3.1.1.4.5 | **Pagos** |  | 400d | 2021-05-20 | 2022-11-30 |  | 22d |  | 3,062,399 |  |
| 503 | 3.1.1.4.5.1 | Pagos BID |  | 400d | 2021-05-20 | 2022-11-30 | 498SS | 22d | 0d | 2,158,056 | Adm. Financ. |
| 504 | 3.1.1.4.5.2 | Pagos CAF |  | 400d | 2021-05-20 | 2022-11-30 | 503SS | 22d | 0d | 704,000 | Adm. Financ. |
| 505 | 3.1.1.4.5.3 | Pagos CL |  | 400d | 2021-05-20 | 2022-11-30 | 504SS | 22d |  | 200,343 | Adm. Financ. |
| 506 | 3.1.2 | **SBCC_14. Supervisión de obras** |  | 710d | 2020-04-09 | 2022-12-28 |  | 2d |  | 257,601 |  |
| 507 | 3.1.2.1 | Etapa previa |  | 20d | 2020-04-09 | 2020-05-06 | 494SS | 2d | 0d |  | Resp. FI |
| 508 | 3.1.2.2 | Expresión de interés |  | 30d | 2020-05-07 | 2020-06-17 | 507 | 2d | 0d |  | Gte. Leg. Y Contr. |
| 509 | 3.1.2.3 | Etapa de contratación |  | 130d | 2020-06-18 | 2020-12-16 | 508 | 2d | 0d |  | Gte. Leg. Y Contr. |
| 510 | 3.1.2.4 | Formalización del contrato |  | 90d | 2020-12-17 | 2021-04-21 | 509 | 2d | 0d |  | Gte. Leg. Y Contr. |
| 511 | 3.1.2.5 | Ejecución del contrato |  | 440d | 2021-04-22 | 2022-12-28 | 510 | 2d | 0d |  | Firma |
| 512 | 3.1.2.6 | **Pagos** |  | 440d | 2021-04-22 | 2022-12-28 |  | 2d |  | 257,601 |  |
| 513 | 3.1.2.6.1 | Pagos BID |  | 440d | 2021-04-22 | 2022-12-28 | 511SS | 2d | 0d | 181,529 | Adm. Financ. |
| 514 | 3.1.2.6.2 | Pagos CAF |  | 440d | 2021-04-22 | 2022-12-28 | 513SS | 2d | 0d | 59,218 | Adm. Financ. |
| 515 | 3.1.2.6.3 | Pagos CL |  | 440d | 2021-04-22 | 2022-12-28 | 514SS | 2d |  | 16,854 | Adm. Financ. |
| 516 | 3.1.3 | Incorporación en los TDR de los supervisores la responsabilidad de monitorear las áreas de servidumbre durante la etapa de construcción |  | 22d | 2016-01-04 | 2016-02-02 | 33SS | 1803d |  |  |  |

| ID | WBS | Task | Type | Duration | Start | Finish | Predecessors | Total slack | Free slack | Cost | Text5 |
| --- | --- | --- | --- | --- | --- | --- | --- | --- | --- | --- | --- |
| 517 | 3.1.4 | **Coordinación de actividades con autoridades competentes** |  | 710d | 2020-04-10 | 2022-12-29 |  | 1d |  |  |  |
| 518 | 3.1.4.1 | Actividades con el Municipio de Arraiján |  | 710d | 2020-04-10 | 2022-12-29 | 494SS+1d | 1d | 0d |  | GSPO |
| 519 | 3.1.4.2 | Actividades con el Municipio de La Chorrera |  | 710d | 2020-04-10 | 2022-12-29 | 518SS | 1d |  |  | GSPO |
| 520 | 3.2. | **Producto 15: Actividades de sensibilización y educación para el manejo adecuado de residuos sólidos, implementadas** |  | 1231d | 2017-07-10 | 2022-03-28 |  | 199d |  | 415,000 |  |
| 521 | 3.2.1 | **SCC_17. Diseño e implementación de un plan de sensibilización para el manejo adecuado de residuos sólidos** |  | 711d | 2017-07-10 | 2020-03-30 |  | 199d |  | 200,000 |  |
| 522 | 3.2.1.1 | Etapa previa |  | 20d | 2017-07-10 | 2017-08-04 | 13FS+66d | 199d | 0d |  | Resp. FI |
| 523 | 3.2.1.2 | Expresión de interés |  | 30d | 2017-08-07 | 2017-09-15 | 522 | 199d | 0d |  | Gte. Leg. Y Contr. |
| 524 | 3.2.1.3 | Etapa de contratación |  | 100d | 2017-09-18 | 2018-02-02 | 523 | 199d | 0d |  | Gte. Leg. Y Contr. |
| 525 | 3.2.1.4 | Formalización del contrato |  | 20d | 2018-02-05 | 2018-03-02 | 524 | 199d | 0d |  | Gte. Leg. Y Contr. |
| 526 | 3.2.1.5 | **Ejecución del contrato** |  | 541d | 2018-03-05 | 2020-03-30 |  | 199d |  |  |  |
| 527 | 3.2.1.5.1 | Diseño del plan de sensibilización |  | 66d | 2018-03-05 | 2018-06-04 | 525 | 199d | 0d |  | Firma |
| 528 | 3.2.1.5.2 | Plan de sensibilización diseñado | milestone | 0d | 2018-06-04 | 2018-06-04 | 527 | 199d | 0d |  |  |
| 529 | 3.2.1.5.3 | Implementación del plan de sensibilización |  | 475d | 2018-06-05 | 2020-03-30 | 528 | 199d | 0d |  | Firma |
| 530 | 3.2.1.5.4 | Actividades de sensibilización realizadas - Año 2 | milestone | 0d | 2019-03-25 | 2019-03-25 | 529SS+210d | 984d |  |  |  |
| 531 | 3.2.1.5.5 | Actividades de sensibilización realizadas - Año 3 | milestone | 0d | 2020-03-30 | 2020-03-30 | 529 | 719d |  |  |  |
| 532 | 3.2.1.6 | **Pagos** |  | 475d | 2018-06-05 | 2020-03-30 |  | 719d |  | 200,000 |  |
| 533 | 3.2.1.6.1 | Pagos BID |  | 475d | 2018-06-05 | 2020-03-30 | 529SS | 719d | 0d | 140,939 | Adm. Financ. |
| 534 | 3.2.1.6.2 | Pagos CAF |  | 475d | 2018-06-05 | 2020-03-30 | 533SS | 719d | 0d | 45,977 | Adm. Financ. |
| 535 | 3.2.1.6.3 | Pagos CL |  | 475d | 2018-06-05 | 2020-03-30 | 534SS | 719d |  | 13,084 | Adm. Financ. |
| 536 | 6.2.2 | Otras actividades a definir |  | 520d | 2020-03-31 | 2022-03-28 | 529 | 199d | 0d | 215,000 | Resp. FI |
| 537 | 3.2.3 | Actividades de sensibilización realizadas - Año 4 | milestone | 0d | 2021-03-29 | 2021-03-29 | 536SS+260d | 459d |  |  |  |
| 538 | 3.2.4 | Actividades de sensibilización realizadas - Año 5 | milestone | 0d | 2022-03-28 | 2022-03-28 | 536 | 199d |  |  |  |
| 539 | 4 | **Administración, Auditoría y Evaluación** |  | 1660d | 2016-08-22 | 2022-12-30 |  | 0d |  | 12,934,000 |  |
| 540 | 4.1 | **Administración del Programa** |  | 1660d | 2016-08-22 | 2022-12-30 |  | 0d |  | 11,984,000 |  |
| 541 | 4.1.1 | **Costos de funcionamiento de la UCPSP** |  | 1660d | 2016-08-22 | 2022-12-30 |  | 0d |  | 11,984,000 |  |
| 542 | 4.1.1.1 | Equipo de la UCPSP |  | 1495d | 2017-04-10 | 2022-12-30 | 13FS+1d | 0d |  |  |  |

| ID | WBS | Task | Duration | Start | Finish | Predecessors | Total slack | Free slack | Cost | Text5 |
| --- | --- | --- | --- | --- | --- | --- | --- | --- | --- | --- |
| 543 | 4.1.1.2 | **Pagos** | 1495d | 2017-04-10 | 2022-12-30 |  | 0d |  | 11,984,000 |  |
| 544 | 4.1.1.2.1 | Pagos BID | 1495d | 2017-04-10 | 2022-12-30 | 542SS | 0d |  | 3,200,000 | Adm. Financ. |
| 545 | 4.1.1.2.2 | Pagos AECID | 1495d | 2017-04-10 | 2022-12-30 | 544SS | 0d |  | 2,000,000 | Adm. Financ. |
| 546 | 4.1.1.2.3 | Pagos CAF | 1495d | 2017-04-10 | 2022-12-30 | 545SS | 0d |  | 2,000,000 | Adm. Financ. |
| 547 | 4.1.1.2.4 | Pagos BCIE | 1495d | 2017-04-10 | 2022-12-30 | 546SS | 0d |  | 2,000,000 | Adm. Financ. |
| 548 | 7.1.1.2.5 | Pagos BEI | 1495d | 2017-04-10 | 2022-12-30 | 547SS | 0d |  | 2,000,000 | Adm. Financ. |
| 549 | 4.1.1.2.5 | Pagos CL | 1495d | 2017-04-10 | 2022-12-30 | 547SS | 0d |  | 784,000 | Adm. Financ. |
| 550 | 4.1.1.3 | Revisión de la estructura organizacional de la UCPSP | 95d | 2016-08-22 | 2016-12-30 | 6 | 1565d |  |  | CG/UCPSP |
| 551 | 4.1.1.4 | Coordinación de acciones el MEF e informar permanentemente sobre los resultados y avances logrados por el Programa | 1495d | 2017-04-10 | 2022-12-30 | 542SS | 0d |  |  | CG/UCPSP |
| 552 | 4.1.1.5 | Reuniones de coordinación con las autoridades de la CGR para socializar aspectos importantes del proyecto y solicitar apoyo requeirdo por parte de la entidad | 1495d | 2017-04-10 | 2022-12-30 | 551SS | 0d |  |  |  |
| 553 | 4.2 | **Auditoría del Programa** | 1495d | 2017-04-10 | 2022-12-30 |  | 0d |  | 600,000 |  |
| 554 | 4.2.1 | **SBCC_18. Contratación de firma para servicios de Auditoría Externa del Programa** | 1495d | 2017-04-10 | 2022-12-30 |  | 0d |  | 600,000 | Gte. Adm. Fin. |
| 555 | 4.2.1.1 | Etapa previa | 20d | 2017-04-10 | 2017-05-05 | 542SS, 13 | 0d |  |  | Gte. Leg. Y Contr. |
| 556 | 4.2.1.2 | Expresión de interés | 30d | 2017-05-08 | 2017-06-16 | 555 | 0d |  |  | Gte. Leg. Y Contr. |
| 557 | 4.2.1.3 | Etapa de contratación | 100d | 2017-06-19 | 2017-11-03 | 556 | 0d |  |  | Gte. Leg. Y Contr. |
| 558 | 4.2.1.4 | Formalización del contrato | 65d | 2017-11-06 | 2018-02-02 | 557 | 0d |  |  | Firma auditora |
| 559 | 4.2.1.5 | Ejecución del contrato | 1280d | 2018-02-05 | 2022-12-30 | 558 | 0d |  |  |  |
| 560 | 4.2.1.6 | **Pagos** | 1280d | 2018-02-05 | 2022-12-30 |  | 0d |  | 600,000 | Adm. Financ. |
| 561 | 4.2.1.6.1 | Pagos BID | 1280d | 2018-02-05 | 2022-12-30 | 558 | 0d |  | 558,000 | Adm. Financ. |
| 562 | 4.2.1.6.2 | Pagos CL | 1280d | 2018-02-05 | 2022-12-30 | 558 | 0d |  | 42,000 |  |
| 563 | 4.3 | **Evaluaciones del Programa** | 735d | 2020-03-05 | 2022-12-28 |  | 2d |  | 350,000 |  |
| 564 | 4.3.1 | **CCIN_21. Consultoría individual para evaluación intermedia del Programa** | 150d | 2020-03-05 | 2020-09-30 |  | 2d |  | 50,000 | Gte. Planificación |
| 565 | 4.3.1.1 | Etapa previa | 20d | 2020-03-05 | 2020-04-01 | 542SS+758d | 2d | 0d |  | Gte. Leg. Y Contr. |
| 566 | 4.3.1.2 | Etapa de contratación | 45d | 2020-04-02 | 2020-06-03 | 565 | 2d | 0d |  | Gte. Leg. Y Contr. |
| 567 | 4.3.1.3 | Formalización del contrato | 20d | 2020-06-04 | 2020-07-01 | 566 | 2d | 0d |  | Consultor |
| 568 | 4.3.1.4 | Ejecución del contrato | 65d | 2020-07-02 | 2020-09-30 | 567 | 2d | 0d |  |  |

| ID | WBS | Task | Type | Duration | Start | Finish | Predecessors | Total slack | Free slack | Cost | Text5 |
| --- | --- | --- | --- | --- | --- | --- | --- | --- | --- | --- | --- |
| 569 | 4.3.1.5 | **Pagos** |  | 65d | 2020-07-02 | 2020-09-30 |  | 587d |  | 50,000 | Adm. Financ. |
| 570 | 4.3.1.5.1 | Pagos BID |  | 65d | 2020-07-02 | 2020-09-30 | 567 | 587d |  | 46,729 | Adm. Financ. |
| 571 | 4.3.1.5.2 | Pagos CL |  | 65d | 2020-07-02 | 2020-09-30 | 567 | 587d |  | 3,271 |  |
| 572 | 4.3.2 | **SCC_19. Consultoría para la evaluación final del programa** |  | 260d | 2021-12-30 | 2022-12-28 |  | 2d |  | 100,000 | Gte. Planificación |
| 573 | 4.3.2.1 | Etapa previa |  | 20d | 2021-12-30 | 2022-01-26 | 568FS+325d | 2d | 0d |  | Gte. Leg. Y Contr. |
| 574 | 4.3.2.2 | Expresión de interés |  | 30d | 2022-01-27 | 2022-03-09 | 573 | 2d | 0d |  | Gte. Leg. Y Contr. |
| 575 | 4.3.2.3 | Etapa de contratación |  | 100d | 2022-03-10 | 2022-07-27 | 574 | 2d | 0d |  | Gte. Leg. Y Contr. |
| 576 | 4.3.2.4 | Formalización del contrato |  | 20d | 2022-07-28 | 2022-08-24 | 575 | 2d | 0d |  | Firma |
| 577 | 4.3.2.5 | Ejecución del contrato |  | 90d | 2022-08-25 | 2022-12-28 | 576 | 2d |  |  |  |
| 578 | 4.3.2.6 | **Pagos** |  | 90d | 2022-08-25 | 2022-12-28 |  | 2d |  | 100,000 | Adm. Financ. |
| 579 | 4.3.2.6.1 | Pagos BID |  | 90d | 2022-08-25 | 2022-12-28 | 576 | 2d |  | 93,458 | Adm. Financ. |
| 580 | 4.3.2.6.2 | Pagos CL |  | 90d | 2022-08-25 | 2022-12-28 | 576 | 2d |  | 6,542 |  |
| 581 | 4.3.3 | **CCIN_22.Consultor individual para la evaluación ex post del Programa** |  | 175d | 2022-04-28 | 2022-12-28 |  | 2d |  | 40,000 | Gte. Planificación |
| 582 | 4.3.3.1 | Etapa previa |  | 20d | 2022-04-28 | 2022-05-25 | 573SS+85d | 2d | 0d |  | Gte. Leg. Y Contr. |
| 583 | 4.3.3.2 | Etapa de contratación |  | 45d | 2022-05-26 | 2022-07-27 | 582 | 2d | 0d |  | Gte. Leg. Y Contr. |
| 584 | 4.3.3.3 | Formalización del contrato |  | 20d | 2022-07-28 | 2022-08-24 | 583 | 2d | 0d |  | Consultor |
| 585 | 4.3.3.4 | Ejecución del contrato |  | 90d | 2022-08-25 | 2022-12-28 | 584 | 2d |  |  |  |
| 586 | 4.3.3.5 | **Pagos** |  | 90d | 2022-08-25 | 2022-12-28 |  | 2d |  | 40,000 | Adm. Financ. |
| 587 | 4.3.3.5.1 | Pagos BID |  | 90d | 2022-08-25 | 2022-12-28 | 584 | 2d |  | 37,200 | Adm. Financ. |
| 588 | 4.3.3.5.2 | Pagos CL |  | 90d | 2022-08-25 | 2022-12-28 | 584 | 2d |  | 2,800 | Gte. Planificación |
| 589 | 7.3.4 | Recursos adicionales |  | 650d | 2020-07-02 | 2022-12-28 | 568SS | 2d |  | 160,000 |  |
| 590 | 0 | Fin de la ejecución del PSACH | milestone | 0d | 2022-12-30 | 2022-12-30 | 559 | 0d |  |  |  |
